# Desarrollo Comercial TV-8

Schedule from MS Project, 2016-01-04 to 2016-01-27, costs in $.

## Calendars

- Estándar: Mon-Fri 08:00-12:00, 13:00-17:00; Sat-Sun off.

## Resources

| Resource | Unit | Rate |
| --- | --- | --- |
| Jonathan Acosta |  | 10 |
| Johnny Viquez |  | 15.5 |
| Grettel Mejia |  | 20 |
| Juan Rojas |  | 22 |
| Electricista |  | 22 |
| Videocámara Mini-DV |  | 6.25 |
| Trípode de cámara |  |  |
| Laboratorio de edición |  | 25 |
| Cinta de vídeo | Cinta de 30 minutos | 5 |
| Viajes |  |  |
| Foco de 600 watios con soporte |  | 2.5 |
| Servicio de Catering |  |  |
| Luis Hanes |  | 18.75 |
| Sandra Campos |  | 19.37 |
| Patricia Monge |  | 9.4 |
| Pedro Mendez |  | 16.75 |
| Jose Garro |  | 18.75 |
| Reflector |  |  |

## Schedule

| ID | WBS | Task | Type | Duration | Start | Finish | Predecessors | Total slack | Resources | Work | Cost |
| --- | --- | --- | --- | --- | --- | --- | --- | --- | --- | --- | --- |
| 1 | 1 | **Preproducción** |  | 8.5d | 2016-01-04 | 2016-01-14 |  | 0d |  | 168h | 3,169.7 |
| 2 | 1.1 | Desarrollo del guión literario |  | 2.5d | 2016-01-04 | 2016-01-06 |  | 0d | Sandra Campos; Patricia Monge | 40h | 575.5 |
| 3 | 1.2 | Desarrollo del guión técnico |  | 3d | 2016-01-06 | 2016-01-11 | 2 | 0d | Grettel Mejia; Patricia Monge | 48h | 705.6 |
| 4 | 1.3 | Localización de exteriores |  | 1d | 2016-01-11 | 2016-01-12 | 3 | 0d | Sandra Campos; Patricia Monge; Cinta de vídeo [4 Cinta de 30 minutos]; Viajes [0.6%] | 16h | 750.2 |
| 5 | 1.4 | Realización de pruebas a actores |  | 2d | 2016-01-12 | 2016-01-14 | 4 | 0d | Pedro Mendez; Sandra Campos; Jonathan Acosta; Patricia Monge; Servicio de Catering [0.2%] | 64h | 1,138.4 |
| 6 | 1.5 | Fin Preproducción | milestone | 0d | 2016-01-14 | 2016-01-14 | 5 | 0d |  |  |  |
| 7 | 2 | **Producción** |  | 5.25d | 2016-01-14 | 2016-01-21 | 1 | 0d |  | 42h | 515 |
| 8 | 2.1 | Ensayo |  | 2.25d | 2016-01-14 | 2016-01-18 |  | 0d | Foco de 600 watios con soporte | 18h | 45 |
| 9 | 2.2 | Rodaje |  | 2d | 2016-01-18 | 2016-01-20 | 8 | 0d | Grettel Mejia | 16h | 320 |
| 10 | 2.3 | Montaje |  | 1d | 2016-01-20 | 2016-01-21 | 9 | 0d | Jose Garro | 8h | 150 |
| 11 | 2.4 | Fin Producción | milestone | 0d | 2016-01-21 | 2016-01-21 | 10 | 0d |  |  |  |
| 12 | 3 | **Post-producción** |  | 3.5d | 2016-01-21 | 2016-01-27 | 7 | 0d |  | 16h | 400 |
| 13 | 3.1 | Ajustes finales |  | 2d | 2016-01-21 | 2016-01-25 |  | 0d | Laboratorio de edición | 16h | 400 |
| 14 | 3.2 | Adición banda de audio |  | 1d | 2016-01-25 | 2016-01-26 | 13 | 0d |  |  |  |
| 15 | 3.3 | Entrega a cliente |  | 4h | 2016-01-26 | 2016-01-27 | 14 | 0d |  |  |  |
