# Desarrollo Condominio

Schedule from MS Project, 2016-01-01 to 2018-05-21, costs in ₡, A marks actual dates.

## Calendars

- Estándar: Mon-Fri 08:00-12:00, 13:00-17:00; Sat-Sun off.

## Resources

| Resource | Rate |
| --- | --- |
| Diseñador | 4500 |
| Ing. Proyecto | 7500 |
| Ing. Disciplina | 6000 |
| Ing. Costos | 3600 |
| Preparador de Borradores | 2400 |
| Programador | 3000 |
| Patrocinador | 9000 |

## Schedule

| ID | WBS | Task | Type | Duration | Start | Finish | Predecessors | Complete | Remaining | Baseline start | Baseline finish | Baseline duration | Baseline 1 start | Baseline 1 finish | Total slack | Free slack | Resources | Work | Actual work | Cost | Baseline cost | Actual cost |
| --- | --- | --- | --- | --- | --- | --- | --- | --- | --- | --- | --- | --- | --- | --- | --- | --- | --- | --- | --- | --- | --- | --- |
| 1 | 1 | **Conceptos** |  | 89d | 2016-01-01 A | 2016-05-04 |  | 24% | 67.86d | 2016-01-01 | 2016-04-28 | 85d | 2016-01-01 | 2016-04-28 | 0d |  |  | 2852h | 640h | 19,721,400 | 19,181,400 | 6,142,000 |
| 2 | 1.1 | **Planeación y control** |  | 25.75d | 2016-01-01 A | 2016-02-05 A |  | 100% |  | 2016-01-01 | 2016-02-01 | 21.75d | 2016-01-01 | 2016-02-01 |  |  |  | 368h | 368h | 3,958,000 | 3,550,000 | 3,958,000 |
| 3 | 1.1.1 | Plan de negocios que identifica la oportunidad del proyecto |  | 6d | 2016-01-01 A | 2016-01-08 A |  | 100% |  | 2016-01-01 | 2016-01-07 | 5d | 2016-01-01 | 2016-01-07 |  |  | Patrocinador | 48h | 48h | 682,000 | 610,000 | 682,000 |
| 4 | 1.1.2 | Definir objetivos del proyecto y necesidades de información |  | 6d | 2016-01-11 A | 2016-01-18 A | 3 | 100% |  | 2016-01-08 | 2016-01-14 | 5d | 2016-01-08 | 2016-01-14 |  |  | Patrocinador | 48h | 48h | 432,000 | 360,000 | 432,000 |
| 5 | 1.1.3 | Identificar los estándares de la industria para los objetivos del proyecto |  | 6d | 2016-01-19 A | 2016-01-26 A | 4 | 100% |  | 2016-01-15 | 2016-01-21 | 5d | 2016-01-15 | 2016-01-21 |  |  | Patrocinador; Ing. Proyecto | 96h | 96h | 792,000 | 660,000 | 792,000 |
| 6 | 1.1.4 | Desarrollar la programación conceptual preliminar y el personal |  | 6d | 2016-01-19 A | 2016-01-26 A | 4 | 100% |  | 2016-01-15 | 2016-01-21 | 5d | 2016-01-15 | 2016-01-21 |  |  | Ing. Proyecto | 48h | 48h | 710,000 | 650,000 | 710,000 |
| 7 | 1.1.5 | Planeación inicial completada | milestone | 0d | 2016-01-26 A | 2016-01-26 A | 6 | 100% |  | 2016-01-21 | 2016-01-21 | 0d | 2016-01-21 | 2016-01-21 |  |  |  |  |  |  |  |  |
| 8 | 1.1.6 | Desarrollar estrategia de asignación de presupuestos |  | 6d | 2016-01-27 A | 2016-02-05 A | 7 | 100% |  | 2016-01-22 | 2016-02-01 | 5d | 2016-01-22 | 2016-02-01 |  |  | Patrocinador | 48h | 48h | 432,000 | 360,000 | 432,000 |
| 9 | 1.1.7 | Desarrollar el modelo de administración y el plan de plantilla |  | 5d | 2016-01-27 A | 2016-02-04 A | 7 | 100% |  | 2016-01-22 | 2016-02-01 | 5d | 2016-01-22 | 2016-02-01 |  |  | Patrocinador; Ing. Proyecto | 80h | 80h | 910,000 | 910,000 | 910,000 |
| 10 | 1.2 | **Evaluación del sitio** |  | 46d | 2016-01-27 A | 2016-03-30 |  | 31% | 31.54d | 2016-01-22 | 2016-03-24 | 45d | 2016-01-22 | 2016-03-24 | 0d |  |  | 896h | 272h | 7,184,000 | 7,052,000 | 2,184,000 |
| 11 | 1.2.1 | Identificar sitios potenciales |  | 12d | 2016-01-27 A | 2016-02-17 A | 7 | 100% |  | 2016-01-22 | 2016-02-11 | 11d | 2016-01-22 | 2016-02-11 |  |  | Patrocinador; Ing. Proyecto | 192h | 192h | 1,584,000 | 1,452,000 | 1,584,000 |
| 12 | 1.2.2 | Definir los requisitos de infraestructura |  | 15d | 2016-02-18 A | 2016-03-09 | 21, 11 | 67% | 5d | 2016-02-12 | 2016-03-03 | 15d | 2016-02-12 | 2016-03-03 | 0d |  | Ing. Proyecto | 120h | 80h | 900,000 | 900,000 | 600,000 |
| 13 | 1.2.3 | Definir las necesidades de utilidades |  | 10d | 2016-02-18 | 2016-03-02 | 21, 11 |  |  | 2016-02-12 | 2016-02-25 | 10d | 2016-02-12 | 2016-02-25 | 5d |  | Ing. Proyecto; Ing. Disciplina | 160h |  | 1,080,000 | 1,080,000 |  |
| 14 | 1.2.4 | Identificar el sitio del proyecto |  | 5d | 2016-02-18 | 2016-02-24 | 21, 11 |  |  | 2016-02-12 | 2016-02-18 | 5d | 2016-02-12 | 2016-02-18 | 10d |  | Ing. Proyecto; Ing. Disciplina | 80h |  | 540,000 | 540,000 |  |
| 15 | 1.2.5 | Evaluar los impactos legales y de medio ambiente |  | 10d | 2016-02-18 | 2016-03-02 | 21, 11 |  |  | 2016-02-12 | 2016-02-25 | 10d | 2016-02-12 | 2016-02-25 | 2d | 0d | Ing. Proyecto; Ing. Disciplina | 160h |  | 1,080,000 | 1,080,000 |  |
| 16 | 1.2.6 | Identificar los requisitos de solicitud de permisos |  | 3d | 2016-03-03 | 2016-03-07 | 15 |  |  | 2016-02-26 | 2016-03-01 | 3d | 2016-02-26 | 2016-03-01 | 2d |  | Ing. Proyecto | 24h |  | 680,000 | 680,000 |  |
| 17 | 1.2.7 | Recomendar el sitio |  | 10d | 2016-03-10 | 2016-03-23 | 15, 12, 13, 14, 16 |  |  | 2016-03-04 | 2016-03-17 | 10d | 2016-03-04 | 2016-03-17 | 0d |  | Patrocinador; Ing. Proyecto | 160h |  | 1,320,000 | 1,320,000 |  |
| 18 | 1.2.8 | Revisión del sitio y la planeación |  | 5d | 2016-03-24 | 2016-03-30 | 17 |  |  | 2016-03-18 | 2016-03-24 | 5d | 2016-03-18 | 2016-03-24 | 0d |  |  |  |  |  |  |  |
| 19 | 1.3 | **Definición del alcance** |  | 51d | 2016-01-27 | 2016-04-06 |  |  |  | 2016-01-22 | 2016-03-31 | 50d | 2016-01-22 | 2016-03-31 | 8d |  |  | 616h |  | 4,176,000 | 4,176,000 |  |
| 20 | 1.3.1 | Desarrollar el alcance general de los objetivos del proyecto |  | 5d | 2016-01-27 | 2016-02-02 | 4, 5 |  |  | 2016-01-22 | 2016-01-28 | 5d | 2016-01-22 | 2016-01-28 | 8d | 0d | Patrocinador; Ing. Proyecto | 80h |  | 660,000 | 660,000 |  |
| 21 | 1.3.2 | Evaluar las necesidades del proyecto y desarrollar una lista de estudio de temas principales |  | 5d | 2016-02-03 | 2016-02-09 | 20 |  |  | 2016-01-29 | 2016-02-04 | 5d | 2016-01-29 | 2016-02-04 | 8d | 0d | Ing. Proyecto; Ing. Disciplina | 80h |  | 540,000 | 540,000 |  |
| 22 | 1.3.3 | Comenzar los estudios principales |  | 2d | 2016-02-10 | 2016-02-11 | 21 |  |  | 2016-02-05 | 2016-02-08 | 2d | 2016-02-05 | 2016-02-08 | 14d | 0d | Ing. Disciplina | 16h |  | 96,000 | 96,000 |  |
| 23 | 1.3.4 | Completar los estudios principales y elaborar recomendaciones |  | 15d | 2016-02-12 | 2016-03-03 | 22 |  |  | 2016-02-09 | 2016-02-29 | 15d | 2016-02-09 | 2016-02-29 | 14d | 0d | Ing. Disciplina | 120h |  | 720,000 | 720,000 |  |
| 24 | 1.3.5 | Desarrollar el alcance específico |  | 5d | 2016-03-04 | 2016-03-10 | 23 |  |  | 2016-03-01 | 2016-03-07 | 5d | 2016-03-01 | 2016-03-07 | 14d | 0d | Ing. Proyecto; Ing. Disciplina | 80h |  | 540,000 | 540,000 |  |
| 25 | 1.3.6 | Preparar la programación conceptual final |  | 10d | 2016-03-11 | 2016-03-24 | 8, 24 |  |  | 2016-03-08 | 2016-03-21 | 10d | 2016-03-08 | 2016-03-21 | 19d |  | Ing. Proyecto; Ing. Disciplina | 160h |  | 1,080,000 | 1,080,000 |  |
| 26 | 1.3.7 | Proporcionar la información del alcance por escrito |  | 5d | 2016-03-31 | 2016-04-06 | 24, 18 |  |  | 2016-03-25 | 2016-03-31 | 5d | 2016-03-25 | 2016-03-31 | 10d |  | Ing. Proyecto; Ing. Disciplina | 80h |  | 540,000 | 540,000 |  |

| ID | WBS | Task | Type | Duration | Start | Finish | Predecessors | Baseline start | Baseline finish | Baseline duration | Baseline 1 start | Baseline 1 finish | Total slack | Free slack | Resources | Work | Cost | Baseline cost |
| --- | --- | --- | --- | --- | --- | --- | --- | --- | --- | --- | --- | --- | --- | --- | --- | --- | --- | --- |
| 27 | 1.4 | **Apoyo disciplinario** |  | 49d | 2016-02-12 | 2016-04-20 |  | 2016-02-09 | 2016-04-14 | 48d | 2016-02-09 | 2016-04-14 | 0d |  |  | 888h | 3,925,200 | 3,925,200 |
| 28 | 1.4.1 | Crear lista de material que se debe entregar |  | 6d | 2016-02-12 | 2016-02-19 | 22 | 2016-02-09 | 2016-02-16 | 6d | 2016-02-09 | 2016-02-16 | 17d | 0d | Ing. Proyecto; Ing. Disciplina | 96h | 648,000 | 648,000 |
| 29 | 1.4.2 | Comenzar las hojas del flujo de trabajo y diseñar los criterios |  | 5d | 2016-02-22 | 2016-02-26 | 28 | 2016-02-17 | 2016-02-23 | 5d | 2016-02-17 | 2016-02-23 | 23d |  | Ing. Disciplina | 40h | 240,000 | 240,000 |
| 30 | 1.4.3 | Comenzar los diseños específicos de disciplina y la lista de equipamiento |  | 11d | 2016-02-22 | 2016-03-07 | 28 | 2016-02-17 | 2016-03-02 | 11d | 2016-02-17 | 2016-03-02 | 17d |  | Ing. Proyecto; Ing. Disciplina | 176h | 1,188,000 | 1,188,000 |
| 31 | 1.4.4 | Comenzar el diseño conceptual |  | 11d | 2016-02-22 | 2016-03-07 | 28 | 2016-02-17 | 2016-03-02 | 11d | 2016-02-17 | 2016-03-02 | 17d |  | Ing. Disciplina; Ing. Proyecto; Preparador de Borradores | 92h | 238,200 | 238,200 |
| 32 | 1.4.5 | Completar las hojas de flujo de trabajo y el diseño de criterios |  | 15d | 2016-03-31 | 2016-04-20 | 29, 24, 23, 18 | 2016-03-25 | 2016-04-14 | 15d | 2016-03-25 | 2016-04-14 | 0d |  | Ing. Disciplina; Preparador de Borradores | 240h | 1,008,000 | 1,008,000 |
| 33 | 1.4.6 | Completar los diseños específicos de disciplina y la lista de equipamiento |  | 15d | 2016-03-31 | 2016-04-20 | 30, 24, 23, 18 | 2016-03-25 | 2016-04-14 | 15d | 2016-03-25 | 2016-04-14 | 0d |  | Ing. Disciplina; Ing. Proyecto; Preparador de Borradores | 124h | 315,000 | 315,000 |
| 34 | 1.4.7 | Completar el diseño conceptual |  | 15d | 2016-03-31 | 2016-04-20 | 31, 24, 23, 18 | 2016-03-25 | 2016-04-14 | 15d | 2016-03-25 | 2016-04-14 | 0d |  | Preparador de Borradores | 120h | 288,000 | 288,000 |
| 35 | 1.5 | **Finalización de la fase conceptual** |  | 10d | 2016-04-21 | 2016-05-04 |  | 2016-04-15 | 2016-04-28 | 10d | 2016-04-15 | 2016-04-28 | 0d |  |  | 84h | 478,200 | 478,200 |
| 36 | 1.5.1 | Preparar el alcance conceptual y estimar la revisión |  | 5d | 2016-04-21 | 2016-04-27 | 25, 8, 9, 26, 32, 33, 34 | 2016-04-15 | 2016-04-21 | 5d | 2016-04-15 | 2016-04-21 | 0d |  | Ing. Proyecto; Ing. Costos; Preparador de Borradores | 44h | 118,200 | 118,200 |
| 37 | 1.5.2 | Evaluar el plan de negocios - incluir los cambios necesarios |  | 5d | 2016-04-28 | 2016-05-04 | 36 | 2016-04-22 | 2016-04-28 | 5d | 2016-04-22 | 2016-04-28 | 0d |  | Patrocinador | 40h | 360,000 | 360,000 |
| 38 | 1.5.3 | Fase conceptual completada | milestone | 0d | 2016-05-04 | 2016-05-04 | 37 | 2016-04-28 | 2016-04-28 | 0d | 2016-04-28 | 2016-04-28 | 0d |  |  |  |  |  |
| 39 | 2 | **Definición** |  | 85d | 2016-05-05 | 2016-08-31 |  | 2016-04-29 | 2016-08-25 | 85d | 2016-04-29 | 2016-08-25 | 0d |  |  | 2764h | 16,653,000 | 16,653,000 |
| 40 | 2.1 | **Planeación y control** |  | 15d | 2016-05-05 | 2016-05-25 |  | 2016-04-29 | 2016-05-19 | 15d | 2016-04-29 | 2016-05-19 | 0d |  |  | 320h | 2,184,000 | 2,184,000 |
| 41 | 2.1.1 | Revisar el plan conceptual |  | 5d | 2016-05-05 | 2016-05-11 | 38 | 2016-04-29 | 2016-05-05 | 5d | 2016-04-29 | 2016-05-05 | 0d |  | Patrocinador; Ing. Proyecto | 80h | 660,000 | 660,000 |
| 42 | 2.1.2 | Actualizar el plan de personal del proyecto |  | 5d | 2016-05-05 | 2016-05-11 | 38 | 2016-04-29 | 2016-05-05 | 5d | 2016-04-29 | 2016-05-05 | 55d |  | Ing. Proyecto; Ing. Disciplina | 80h | 540,000 | 540,000 |
| 43 | 2.1.3 | Identificar el material de ingeniería que se debe entregar en la fase de definición |  | 5d | 2016-05-12 | 2016-05-18 | 41 | 2016-05-06 | 2016-05-12 | 5d | 2016-05-06 | 2016-05-12 | 15d | 0d | Ing. Proyecto; Ing. Disciplina | 80h | 540,000 | 540,000 |
| 44 | 2.1.4 | Desarrollar el plan de imprevistos del proyecto y los factores de costos indirectos |  | 5d | 2016-05-19 | 2016-05-25 | 43 | 2016-05-13 | 2016-05-19 | 5d | 2016-05-13 | 2016-05-19 | 45d |  | Ing. Proyecto; Ing. Costos | 80h | 444,000 | 444,000 |
| 45 | 2.2 | **Definición del alcance** |  | 45d | 2016-05-12 | 2016-07-13 |  | 2016-05-06 | 2016-07-07 | 45d | 2016-05-06 | 2016-07-07 | 0d |  |  | 760h | 4,620,000 | 4,620,000 |
| 46 | 2.2.1 | Revisar la lista de estudios |  | 5d | 2016-05-12 | 2016-05-18 | 41 | 2016-05-06 | 2016-05-12 | 5d | 2016-05-06 | 2016-05-12 | 0d |  | Ing. Proyecto; Ing. Disciplina | 80h | 540,000 | 540,000 |
| 47 | 2.2.2 | Proporcionar los requisitos de diseño |  | 5d | 2016-05-19 | 2016-05-25 | 43 | 2016-05-13 | 2016-05-19 | 5d | 2016-05-13 | 2016-05-19 | 15d |  | Ing. Disciplina | 40h | 240,000 | 240,000 |
| 48 | 2.2.3 | Establecer los requisitos de datos de las empresas auxiliares y los presupuestos de equipamiento |  | 10d | 2016-05-19 | 2016-06-01 | 46 | 2016-05-13 | 2016-05-26 | 10d | 2016-05-13 | 2016-05-26 | 0d |  | Ing. Proyecto; Ing. Disciplina | 160h | 1,080,000 | 1,080,000 |
| 49 | 2.2.4 | Definir la lista de equipamiento y sus especificaciones |  | 10d | 2016-06-02 | 2016-06-15 | 41, 48 | 2016-05-27 | 2016-06-09 | 10d | 2016-05-27 | 2016-06-09 | 0d |  | Ing. Proyecto; Ing. Disciplina | 160h | 1,080,000 | 1,080,000 |
| 50 | 2.2.5 | Generar el diseño de canalizaciones y los instrumentos (PID) |  | 20d | 2016-06-16 | 2016-07-13 | 43, 48, 49 | 2016-06-10 | 2016-07-07 | 20d | 2016-06-10 | 2016-07-07 | 0d |  | Ing. Disciplina; Diseñador | 320h | 1,680,000 | 1,680,000 |

| ID | WBS | Task | Type | Duration | Start | Finish | Predecessors | Baseline start | Baseline finish | Baseline duration | Baseline 1 start | Baseline 1 finish | Total slack | Free slack | Resources | Work | Cost | Baseline cost |
| --- | --- | --- | --- | --- | --- | --- | --- | --- | --- | --- | --- | --- | --- | --- | --- | --- | --- | --- |
| 51 | 2.3 | **Apoyo disciplinario** |  | 40d | 2016-05-19 | 2016-07-13 |  | 2016-05-13 | 2016-07-07 | 40d | 2016-05-13 | 2016-07-07 | 0d |  |  | 880h | 4,800,000 | 4,800,000 |
| 52 | 2.3.1 | Revisar los requisitos legales del organismo de control |  | 20d | 2016-05-19 | 2016-06-15 | 46 | 2016-05-13 | 2016-06-09 | 20d | 2016-05-13 | 2016-06-09 | 0d |  | Ing. Disciplina | 160h | 960,000 | 960,000 |
| 53 | 2.3.2 | Generar los planes generales de disposición y del sitio |  | 20d | 2016-06-16 | 2016-07-13 | 47, 43, 48, 49 | 2016-06-10 | 2016-07-07 | 20d | 2016-06-10 | 2016-07-07 | 0d |  | Ing. Disciplina; Diseñador | 320h | 1,680,000 | 1,680,000 |
| 54 | 2.3.3 | Desarrollar especificaciones, listas y diseños de control específicos de la disciplina |  | 20d | 2016-06-16 | 2016-07-13 | 43, 52, 49 | 2016-06-10 | 2016-07-07 | 20d | 2016-06-10 | 2016-07-07 | 0d |  | Ing. Disciplina; Diseñador | 320h | 1,680,000 | 1,680,000 |
| 55 | 2.3.4 | Evaluar la información de viabilidad procedente de la información de construcción |  | 10d | 2016-06-30 | 2016-07-13 | 53SS+5%, 50SS+5%, 54SS+5% | 2016-06-24 | 2016-07-07 | 10d | 2016-06-24 | 2016-07-07 | 10d |  | Ing. Disciplina | 80h | 480,000 | 480,000 |
| 56 | 2.4 | **Finalización de la fase de definición** |  | 45d | 2016-06-30 | 2016-08-31 |  | 2016-06-24 | 2016-08-25 | 45d | 2016-06-24 | 2016-08-25 | 0d |  |  | 804h | 5,049,000 | 5,049,000 |
| 57 | 2.4.1 | Generar el documento de ámbito (incluida la infraestructura) |  | 20d | 2016-06-30 | 2016-07-27 | 53SS+5%, 50SS+5%, 54SS+5% | 2016-06-24 | 2016-07-21 | 20d | 2016-06-24 | 2016-07-21 | 0d |  | Ing. Proyecto; Ing. Disciplina | 320h | 2,160,000 | 2,160,000 |
| 58 | 2.4.2 | Generar la estimación de capital del proyecto |  | 15d | 2016-06-30 | 2016-07-20 | 53SS+5%, 50SS+5% | 2016-06-24 | 2016-07-14 | 15d | 2016-06-24 | 2016-07-14 | 5d |  | Ing. Costos | 120h | 432,000 | 432,000 |
| 59 | 2.4.3 | Establecer la programación del proyecto |  | 10d | 2016-06-30 | 2016-07-13 | 53SS+5%, 50SS+5% | 2016-06-24 | 2016-07-07 | 10d | 2016-06-24 | 2016-07-07 | 10d |  | Ing. Proyecto; Programador | 160h | 840,000 | 840,000 |
| 60 | 2.4.4 | Revisar definiciones, ámbito y estimaciones |  | 5d | 2016-07-28 | 2016-08-03 | 57, 58, 59, 42, 48, 53, 44, 50, 55 | 2016-07-22 | 2016-07-28 | 5d | 2016-07-22 | 2016-07-28 | 0d |  | Patrocinador; Ing. Proyecto; Ing. Costos | 44h | 177,000 | 177,000 |
| 61 | 2.4.5 | Ámbito completado - presentar estimación de costos | milestone | 0d | 2016-08-03 | 2016-08-03 | 60 | 2016-07-28 | 2016-07-28 | 0d | 2016-07-28 | 2016-07-28 | 0d |  |  |  |  |  |
| 62 | 2.4.6 | Asignar el dinero del proyecto |  | 20d | 2016-08-04 | 2016-08-31 | 61 | 2016-07-29 | 2016-08-25 | 20d | 2016-07-29 | 2016-08-25 | 0d |  | Patrocinador | 160h | 1,440,000 | 1,440,000 |
| 63 | 2.4.7 | Proyecto autorizado | milestone | 0d | 2016-08-31 | 2016-08-31 | 62 | 2016-08-25 | 2016-08-25 | 0d | 2016-08-25 | 2016-08-25 | 0d |  |  |  |  |  |
| 64 | 3 | **Diseño** |  | 201.25d | 2016-09-01 | 2017-06-09 |  | 2016-08-26 | 2017-06-05 | 201.25d | 2016-08-26 | 2017-06-05 | 0d |  |  | 20804h | 110,403,000 | 110,403,000 |
| 65 | 3.1 | **Planeación y control** |  | 166d | 2016-09-01 | 2017-04-20 |  | 2016-08-26 | 2017-04-14 | 166d | 2016-08-26 | 2017-04-14 | 0d |  |  | 7364h | 50,745,000 | 50,745,000 |
| 66 | 3.1.1 | Revisar definiciones, ámbito y estimaciones |  | 1d | 2016-09-01 | 2016-09-01 | 63 | 2016-08-26 | 2016-08-26 | 1d | 2016-08-26 | 2016-08-26 | 0d |  | Patrocinador; Ing. Proyecto | 16h | 132,000 | 132,000 |
| 67 | 3.1.2 | Desarrollar o actualizar procedimientos del proyecto |  | 10d | 2016-09-02 | 2016-09-15 | 66 | 2016-08-29 | 2016-09-09 | 10d | 2016-08-29 | 2016-09-09 | 0d |  | Ing. Proyecto | 80h | 600,000 | 600,000 |
| 68 | 3.1.3 | Finalizar la programación del diseño y la construcción |  | 6d | 2016-09-02 | 2016-09-09 | 66 | 2016-08-29 | 2016-09-05 | 6d | 2016-08-29 | 2016-09-05 | 4d | 0d | Programador; Ing. Proyecto | 96h | 504,000 | 504,000 |
| 69 | 3.1.4 | Desarrollar y administrar lista de asuntos |  | 100d | 2016-09-02 | 2017-01-19 | 66 | 2016-08-29 | 2017-01-13 | 100d | 2016-08-29 | 2017-01-13 | 98.25d |  | Ing. Proyecto | 800h | 6,000,000 | 6,000,000 |
| 70 | 3.1.5 | Obtener el equipamiento con plazo de entrega largo |  | 133d | 2016-09-06 | 2017-03-09 | 84 | 2016-08-31 | 2017-03-03 | 133d | 2016-08-31 | 2017-03-03 | 58d | 30.5d | Ing. Proyecto | 1064h | 7,980,000 | 7,980,000 |
| 71 | 3.1.6 | Establecer e implantar el plan de obtención de equipamiento y de contratación |  | 3d | 2016-09-07 | 2016-09-09 | 68SS+5%, 84 | 2016-09-01 | 2016-09-05 | 3d | 2016-09-01 | 2016-09-05 | 4d |  | Patrocinador; Ing. Proyecto | 48h | 396,000 | 396,000 |
| 72 | 3.1.7 | Planear la fase de diseño y de personal |  | 3d | 2016-09-16 | 2016-09-20 | 66, 67 | 2016-09-12 | 2016-09-14 | 3d | 2016-09-12 | 2016-09-14 | 7.75d |  | Ing. Proyecto | 24h | 180,000 | 180,000 |
| 73 | 3.1.8 | Definir la presentación de ingeniería y el contenido de las especificaciones y los diseños |  | 3d | 2016-09-16 | 2016-09-20 | 68SS+5%, 67, 71 | 2016-09-12 | 2016-09-14 | 3d | 2016-09-12 | 2016-09-14 | 0d |  | Ing. Proyecto; Ing. Disciplina | 48h | 324,000 | 324,000 |
| 74 | 3.1.9 | Implantar el control de documentos |  | 5d | 2016-09-16 | 2016-09-22 | 67 | 2016-09-12 | 2016-09-16 | 5d | 2016-09-12 | 2016-09-16 | 38.25d | 5d | Ing. Proyecto | 40h | 300,000 | 300,000 |
| 75 | 3.1.10 | Establecer el seguimiento del proyecto |  | 5d | 2016-09-16 | 2016-09-22 | 67, 71 | 2016-09-12 | 2016-09-16 | 5d | 2016-09-12 | 2016-09-16 | 38.25d | 5d | Ing. Proyecto | 40h | 300,000 | 300,000 |
| 76 | 3.1.11 | Desarrollar el control de costo del proyecto y el sistema de valor acumulado |  | 10d | 2016-09-16 | 2016-09-29 | 66, 67 | 2016-09-12 | 2016-09-23 | 10d | 2016-09-12 | 2016-09-23 | 33.25d | 0d | Ing. Proyecto; Programador; Ing. Costos | 84h | 309,000 | 309,000 |
| 77 | 3.1.12 | Finalizar la lista de material que se debe entregar |  | 10d | 2016-09-16 | 2016-09-30 | 66, 73SS+2.5%, 71 | 2016-09-12 | 2016-09-26 | 10d | 2016-09-12 | 2016-09-26 | 0d |  | Ing. Proyecto; Ing. Disciplina | 160h | 1,080,000 | 1,080,000 |
| 78 | 3.1.13 | Implantar el sistema de informes del proyecto |  | 145d | 2016-09-30 | 2017-04-20 | 76, 67, 74, 75 | 2016-09-26 | 2017-04-14 | 145d | 2016-09-26 | 2017-04-14 | 33.25d |  | Ing. Proyecto | 1160h | 8,700,000 | 8,700,000 |
| 79 | 3.1.14 | Aprobación de facturas y de pagos por contratos |  | 100d | 2016-10-14 | 2017-03-02 | 85 | 2016-10-10 | 2017-02-24 | 100d | 2016-10-10 | 2017-02-24 | 68.25d |  | Ing. Proyecto | 800h | 6,000,000 | 6,000,000 |
| 80 | 3.1.15 | Obtener el equipamiento |  | 123d | 2016-10-21 | 2017-04-11 | 85, 88SS+5% | 2016-10-17 | 2017-04-05 | 123d | 2016-10-17 | 2017-04-05 | 27.5d | 0d | Ing. Proyecto | 984h | 7,380,000 | 7,380,000 |
| 81 | 3.1.16 | Implantar la aceleración de procesos, incluidos los diseños de las empresas auxiliares |  | 100d | 2016-10-21 | 2017-03-09 | 85, 88SS+5% | 2016-10-17 | 2017-03-03 | 100d | 2016-10-17 | 2017-03-03 | 63.25d |  | Ing. Proyecto; Programador | 1600h | 8,400,000 | 8,400,000 |
| 82 | 3.1.17 | Plan de enseñanza inicial |  | 20d | 2017-02-22 | 2017-03-21 | 89 | 2017-02-16 | 2017-03-15 | 20d | 2017-02-16 | 2017-03-15 | 55.25d |  | Ing. Proyecto; Ing. Disciplina | 320h | 2,160,000 | 2,160,000 |

| ID | WBS | Task | Duration | Start | Finish | Predecessors | Baseline start | Baseline finish | Baseline duration | Baseline 1 start | Baseline 1 finish | Total slack | Free slack | Resources | Work | Cost | Baseline cost |
| --- | --- | --- | --- | --- | --- | --- | --- | --- | --- | --- | --- | --- | --- | --- | --- | --- | --- |
| 83 | 3.2 | **Ajuste del ámbito** | 123d | 2016-09-02 | 2017-02-21 |  | 2016-08-29 | 2017-02-15 | 123d | 2016-08-29 | 2017-02-15 | 5d |  |  | 2032h | 11,976,000 | 11,976,000 |
| 84 | 3.2.1 | Actualizar los criterios de diseño del proyecto | 2d | 2016-09-02 | 2016-09-05 | 66 | 2016-08-29 | 2016-08-30 | 2d | 2016-08-29 | 2016-08-30 | 5d | 0d | Ing. Proyecto; Ing. Disciplina | 32h | 216,000 | 216,000 |
| 85 | 3.2.2 | Asunto de diseño: lista de equipamientos | 30d | 2016-09-02 | 2016-10-13 | 66 | 2016-08-29 | 2016-10-07 | 30d | 2016-08-29 | 2016-10-07 | 27.5d | 0d | Ing. Disciplina | 240h | 1,440,000 | 1,440,000 |
| 86 | 3.2.3 | Asunto para diseño de disciplina: canalización y diseño de los instrumentos (PID) | 30d | 2016-09-21 | 2016-11-01 | 73 | 2016-09-15 | 2016-10-26 | 30d | 2016-09-15 | 2016-10-26 | 35.25d | 0d | Ing. Disciplina; Diseñador | 480h | 2,520,000 | 2,520,000 |
| 87 | 3.2.4 | Asunto para el diseño de la disciplina: diseño de administración general (AG) y plan del sitio | 30d | 2016-09-21 | 2016-11-01 | 73 | 2016-09-15 | 2016-10-26 | 30d | 2016-09-15 | 2016-10-26 | 35.25d | 0d | Ing. Disciplina; Diseñador | 480h | 2,520,000 | 2,520,000 |
| 88 | 3.2.5 | Especificaciones del equipamiento, ofertas, selección de empresas auxiliares | 40d | 2016-09-23 | 2016-11-17 | 73, 85SS+5% | 2016-09-19 | 2016-11-11 | 40d | 2016-09-19 | 2016-11-11 | 27.5d | 0d | Ing. Proyecto; Ing. Disciplina | 640h | 4,320,000 | 4,320,000 |
| 89 | 3.2.6 | Procesar las descripciones funcionales del equipamiento | 20d | 2017-01-25 | 2017-02-21 | 106SS+7.5% | 2017-01-19 | 2017-02-15 | 20d | 2017-01-19 | 2017-02-15 | 35.25d | 0d | Ing. Disciplina | 160h | 960,000 | 960,000 |
| 90 | 3.3 | **Apoyo disciplinario** | 200.25d | 2016-09-02 | 2017-06-09 |  | 2016-08-29 | 2017-06-05 | 200.25d | 2016-08-29 | 2017-06-05 | 0d |  |  | 11408h | 47,682,000 | 47,682,000 |
| 91 | 3.3.1 | Establecer la disciplina por que se regirán los requisitos del código | 2d | 2016-09-02 | 2016-09-05 | 66 | 2016-08-29 | 2016-08-30 | 2d | 2016-08-29 | 2016-08-30 | 18.75d |  | Ing. Disciplina | 16h | 96,000 | 96,000 |
| 92 | 3.3.2 | Revisar y finalizar los estándares de disciplina y las especificaciones | 5d | 2016-09-30 | 2016-10-07 | 73, 91, 72, 77 | 2016-09-26 | 2016-10-03 | 5d | 2016-09-26 | 2016-10-03 | 0d |  | Ing. Disciplina | 40h | 240,000 | 240,000 |
| 93 | 3.3.3 | **Comenzar el diseño de la disciplina** | 55d | 2016-10-07 | 2016-12-23 |  | 2016-10-03 | 2016-12-19 | 55d | 2016-10-03 | 2016-12-19 | 0d |  |  | 3280h | 17,220,000 | 17,220,000 |
| 94 | 3.3.3.1 | Comenzar el diseño de la arquitectura | 25d | 2016-10-07 | 2016-11-11 | 92 | 2016-10-03 | 2016-11-07 | 25d | 2016-10-03 | 2016-11-07 | 0d |  | Ing. Disciplina; Diseñador | 400h | 2,100,000 | 2,100,000 |
| 95 | 3.3.3.2 | Comenzar el diseño civil | 30d | 2016-10-14 | 2016-11-25 | 94SS+5d | 2016-10-10 | 2016-11-21 | 30d | 2016-10-10 | 2016-11-21 | 0d |  | Ing. Disciplina; Diseñador | 480h | 2,520,000 | 2,520,000 |
| 96 | 3.3.3.3 | Comenzar el diseño mecánico | 30d | 2016-10-21 | 2016-12-02 | 95SS+5d | 2016-10-17 | 2016-11-28 | 30d | 2016-10-17 | 2016-11-28 | 0d |  | Ing. Disciplina; Diseñador | 480h | 2,520,000 | 2,520,000 |
| 97 | 3.3.3.4 | Comenzar el diseño de canalizaciones | 30d | 2016-10-28 | 2016-12-09 | 96SS+5d | 2016-10-24 | 2016-12-05 | 30d | 2016-10-24 | 2016-12-05 | 0d |  | Ing. Disciplina; Diseñador | 480h | 2,520,000 | 2,520,000 |
| 98 | 3.3.3.5 | Comenzar el diseño estructural | 30d | 2016-10-14 | 2016-11-25 | 94SS+5d | 2016-10-10 | 2016-11-21 | 30d | 2016-10-10 | 2016-11-21 | 20d |  | Ing. Disciplina; Diseñador | 480h | 2,520,000 | 2,520,000 |
| 99 | 3.3.3.6 | Comenzar el diseño eléctrico | 30d | 2016-11-04 | 2016-12-16 | 97SS+5d | 2016-10-31 | 2016-12-12 | 30d | 2016-10-31 | 2016-12-12 | 0d |  | Ing. Disciplina; Diseñador | 480h | 2,520,000 | 2,520,000 |
| 100 | 3.3.3.7 | Comenzar el diseño de instrumentación | 30d | 2016-11-11 | 2016-12-23 | 99SS+5d | 2016-11-07 | 2016-12-19 | 30d | 2016-11-07 | 2016-12-19 | 0d |  | Ing. Disciplina; Diseñador | 480h | 2,520,000 | 2,520,000 |
| 101 | 3.3.4 | Implantar la primera revisión de calidad | 5d | 2016-12-14 | 2016-12-21 | 94SS+7.5%, 95SS+7.5%, 96SS+7.5%, 97SS+7.5%, 98SS+7.5%, 99SS+7.5%, 100SS+7.5% | 2016-12-08 | 2016-12-15 | 5d | 2016-12-08 | 2016-12-15 | 0d |  | Ing. Disciplina | 40h | 240,000 | 240,000 |
| 102 | 3.3.5 | Revisión del diseño de empresas auxiliares (todas las disciplinas) | 60d | 2016-12-02 | 2017-02-24 | 80SS+2.5%, 70SS+2.5% | 2016-11-28 | 2017-02-20 | 60d | 2016-11-28 | 2017-02-20 | 27.5d | 0d | Ing. Disciplina | 480h | 2,880,000 | 2,880,000 |
| 103 | 3.3.6 | Certificación del diseño de empresas auxiliares (todas las disciplinas) | 5d | 2017-02-24 | 2017-03-03 | 102 | 2017-02-20 | 2017-02-27 | 5d | 2017-02-20 | 2017-02-27 | 27.5d |  | Ing. Disciplina; Ing. Proyecto | 80h | 540,000 | 540,000 |
| 104 | 3.3.7 | Revisión cruzada de la ingeniería de las disciplinas | 5d | 2016-12-14 | 2016-12-21 | 94SS+7.5%, 95SS+7.5%, 96SS+7.5%, 97SS+7.5%, 98SS+7.5%, 99SS+7.5%, 100SS+7.5% | 2016-12-08 | 2016-12-15 | 5d | 2016-12-08 | 2016-12-15 | 0d |  | Ing. Disciplina; Diseñador | 80h | 420,000 | 420,000 |
| 105 | 3.3.8 | Completar la lista de equipamientos | 90d | 2016-10-14 | 2017-02-16 | 85 | 2016-10-10 | 2017-02-10 | 90d | 2016-10-10 | 2017-02-10 | 38.25d |  | Ing. Disciplina; Ing. Proyecto | 1440h | 9,720,000 | 9,720,000 |
| 106 | 3.3.9 | Completar los PID | 80d | 2016-11-02 | 2017-02-21 | 86 | 2016-10-27 | 2017-02-15 | 80d | 2016-10-27 | 2017-02-15 | 35.25d | 0d | Ing. Disciplina; Diseñador; Preparador de Borradores | 644h | 1,557,000 | 1,557,000 |
| 107 | 3.3.10 | Completar los AG y el plan del sitio | 80d | 2016-11-02 | 2017-02-21 | 87 | 2016-10-27 | 2017-02-15 | 80d | 2016-10-27 | 2017-02-15 | 35.25d |  | Ing. Disciplina; Diseñador; Preparador de Borradores | 644h | 1,557,000 | 1,557,000 |

| ID | WBS | Task | Type | Duration | Start | Finish | Predecessors | Baseline start | Baseline finish | Baseline duration | Baseline 1 start | Baseline 1 finish | Total slack | Free slack | Resources | Work | Cost | Baseline cost |
| --- | --- | --- | --- | --- | --- | --- | --- | --- | --- | --- | --- | --- | --- | --- | --- | --- | --- | --- |
| 108 | 3.3.11 | **Completar el diseño de las disciplinas** |  | 80d | 2016-12-21 | 2017-04-12 |  | 2016-12-15 | 2017-04-06 | 80d | 2016-12-15 | 2017-04-06 | 0d |  |  | 4108h | 9,939,000 | 9,939,000 |
| 109 | 3.3.11.1 | Completar el diseño de la arquitectura |  | 70d | 2016-12-21 | 2017-03-29 | 104, 87, 101 | 2016-12-15 | 2017-03-23 | 70d | 2016-12-15 | 2017-03-23 | 10d | 7.5d | Ing. Disciplina; Diseñador; Preparador de Borradores | 564h | 1,365,000 | 1,365,000 |
| 110 | 3.3.11.2 | Completar el diseño civil |  | 70d | 2016-12-21 | 2017-03-29 | 104, 87, 101 | 2016-12-15 | 2017-03-23 | 70d | 2016-12-15 | 2017-03-23 | 10d |  | Ing. Disciplina; Diseñador; Preparador de Borradores | 564h | 1,365,000 | 1,365,000 |
| 111 | 3.3.11.3 | Completar el diseño mecánico |  | 70d | 2016-12-21 | 2017-03-29 | 104, 87, 101 | 2016-12-15 | 2017-03-23 | 70d | 2016-12-15 | 2017-03-23 | 10d | 7.5d | Ing. Disciplina; Diseñador; Preparador de Borradores | 564h | 1,365,000 | 1,365,000 |
| 112 | 3.3.11.4 | Completar el diseño estructural |  | 70d | 2016-12-21 | 2017-03-29 | 104, 87, 101 | 2016-12-15 | 2017-03-23 | 70d | 2016-12-15 | 2017-03-23 | 10d | 7.5d | Ing. Disciplina; Diseñador; Preparador de Borradores | 564h | 1,365,000 | 1,365,000 |
| 113 | 3.3.11.5 | Completar el diseño de canalización |  | 70d | 2016-12-21 | 2017-03-29 | 104, 86, 101 | 2016-12-15 | 2017-03-23 | 70d | 2016-12-15 | 2017-03-23 | 10d | 7.5d | Ing. Disciplina; Diseñador; Preparador de Borradores | 564h | 1,365,000 | 1,365,000 |
| 114 | 3.3.11.6 | Completar el diseño eléctrico |  | 80d | 2016-12-21 | 2017-04-12 | 104, 86, 101 | 2016-12-15 | 2017-04-06 | 80d | 2016-12-15 | 2017-04-06 | 0d |  | Ing. Disciplina; Diseñador; Preparador de Borradores | 644h | 1,557,000 | 1,557,000 |
| 115 | 3.3.11.7 | Completar el diseño de la instrumentación |  | 80d | 2016-12-21 | 2017-04-12 | 104, 86, 101 | 2016-12-15 | 2017-04-06 | 80d | 2016-12-15 | 2017-04-06 | 0d |  | Ing. Disciplina; Diseñador; Preparador de Borradores | 644h | 1,557,000 | 1,557,000 |
| 116 | 3.3.12 | Implantar la segunda revisión de calidad |  | 5d | 2017-03-15 | 2017-03-22 | 109SS+7.5%, 111SS+7.5%, 112SS+7.5%, 113SS+7.5%, 114SS+7.5% | 2017-03-09 | 2017-03-16 | 5d | 2017-03-09 | 2017-03-16 | 15d |  | Ing. Disciplina | 40h | 240,000 | 240,000 |
| 117 | 3.3.13 | Implantar revisiones de cumplimiento con el código y la seguridad |  | 10d | 2017-03-15 | 2017-03-29 | 109SS+7.5%, 111SS+7.5%, 112SS+7.5%, 113SS+7.5%, 114SS+7.5% | 2017-03-09 | 2017-03-23 | 10d | 2017-03-09 | 2017-03-23 | 10d |  | Ing. Disciplina | 80h | 480,000 | 480,000 |
| 118 | 3.3.14 | **Fase de diseño completada** |  | 42d | 2017-04-12 | 2017-06-09 |  | 2017-04-06 | 2017-06-05 | 42d | 2017-04-06 | 2017-06-05 | 0d |  |  | 436h | 2,553,000 | 2,553,000 |
| 119 | 3.3.14.1 | Comprobar y volver a escribir borradores de diseño y listas (todas las disciplinas) |  | 15d | 2017-04-12 | 2017-05-03 | 109, 110, 111, 112, 113, 114, 115, 89, 103, 105, 106, 107, 116, 117 | 2017-04-06 | 2017-04-27 | 15d | 2017-04-06 | 2017-04-27 | 0d |  | Ing. Disciplina; Diseñador; Preparador de Borradores | 124h | 309,000 | 309,000 |
| 120 | 3.3.14.2 | Elaborar borradores de permisos y cálculos de cumplimiento del código (todas las disciplinas) |  | 5d | 2017-05-03 | 2017-05-10 | 119 | 2017-04-27 | 2017-05-04 | 5d | 2017-04-27 | 2017-05-04 | 0d |  | Ing. Disciplina; Ing. Proyecto | 80h | 540,000 | 540,000 |
| 121 | 3.3.14.3 | Autorizar a ingeniería para tramitar permisos, licitación y construcción |  | 15d | 2017-05-10 | 2017-05-31 | 120 | 2017-05-04 | 2017-05-25 | 15d | 2017-05-04 | 2017-05-25 | 0d |  | Ing. Proyecto | 120h | 900,000 | 900,000 |
| 122 | 3.3.14.4 | Selección de personal auxiliar y revisión de contratos |  | 5d | 2017-05-31 | 2017-06-07 | 121 | 2017-05-25 | 2017-06-01 | 5d | 2017-05-25 | 2017-06-01 | 0d |  | Ing. Disciplina; Ing. Proyecto | 80h | 540,000 | 540,000 |
| 123 | 3.3.14.5 | Proyecto completado - informe de finalización, preparar bocetos de registro |  | 2d | 2017-06-07 | 2017-06-09 | 122, 69, 78, 80, 81, 79, 82, 70 | 2017-06-01 | 2017-06-05 | 2d | 2017-06-01 | 2017-06-05 | 0d |  | Ing. Proyecto; Patrocinador | 32h | 264,000 | 264,000 |
| 124 | 4 | **Construcción** |  | 246d | 2017-06-09 | 2018-05-21 | 123 | 2017-06-05 | 2018-05-15 | 246d | 2017-06-05 | 2018-05-15 | 0d |  |  |  |  |  |
| 125 | 4.1 | Seleccionar personal auxiliar de construcción |  | 30d | 2017-06-09 | 2017-07-21 | 123 | 2017-06-05 | 2017-07-17 | 30d | 2017-06-05 | 2017-07-17 | 0d |  |  |  |  |  |
| 126 | 4.2 | Traslado al lugar de trabajo |  | 20d | 2017-07-21 | 2017-08-18 | 125 | 2017-07-17 | 2017-08-14 | 20d | 2017-07-17 | 2017-08-14 | 0d |  |  |  |  |  |
| 127 | 4.3 | Construcción |  | 196d | 2017-08-18 | 2018-05-21 | 126 | 2017-08-14 | 2018-05-15 | 196d | 2017-08-14 | 2018-05-15 | 0d |  |  |  |  |  |
| 128 | 4.4 | Construcción completada | milestone | 0d | 2018-05-21 | 2018-05-21 | 127 | 2018-05-15 | 2018-05-15 | 0d | 2018-05-15 | 2018-05-15 | 0d |  |  |  |  |  |
