# Desarrollo Comercial TV-25

Schedule from MS Project, 2016-03-07 to 2016-10-24, costs in $, A marks actual dates.

## Calendars

- Horario Nocturno: Mon 23:00-24:00; Tue-Fri 00:00-03:00, 04:00-08:00, 23:00-24:00; Sat 00:00-03:00, 04:00-08:00; Sun off.
- Estándar: Mon-Fri 08:00-12:00, 13:00-17:00; Sat-Sun off.

## Resources

| Resource | Group | Unit | Rate | Cost per use |
| --- | --- | --- | --- | --- |
| Cámara de 16 mm | Equipo |  | 60 |  |
| Película de 16 mm | Material | 100 metros | 30 |  |
| Foco de 500 watios | Equipo |  | 20 |  |
| Anny Pérez | Creativos |  | 130 |  |
| Trípode de cámara | Equipo |  |  |  |
| Clara Blanco | Producción |  | 23.88 |  |
| Grúa | Equipo |  |  |  |
| Daniel Romero | Creativos |  | 18.75 |  |
| David Casas | Creativos |  | 18.75 |  |
| Dolores Díaz | Equipo |  |  |  |
| Douglas Henao | Producción |  | 19.2 |  |
| Laboratorio de edición | Equipo |  | 31.25 | 25 |
| Electricista | Auxiliares |  | 50 |  |
| Erick Lagos | Producción |  | 18.5 |  |
| Erick Muslera | Creativos |  | 18.75 |  |
| Floría Víquez | Producción |  | 25 |  |
| Frank Solano | Auxiliares |  | 17 |  |
| Jenny Solera | Producción |  | 21.75 |  |
| Jimmy Lépiz | Creativos |  | 9.38 |  |
| José Bolaños | Producción |  | 21.75 |  |
| Johnny Salas | Producción |  | 25 |  |
| José Matera | Creativos |  | 18.75 |  |
| Randall Cañas | Creativos |  | 16 |  |
| Kathia Wallace | Producción |  | 20 | 100 |
| Kenneth Orozco | Auxiliares |  | 17 |  |
| Kelly Borbón | Production |  | 16.4 |  |
| Linda Díaz | Producción |  | 27 |  |
| Lisa Calero | Producción |  | 16 |  |
| Mark O'hara | Producción |  | 25 |  |
| Max Benítez | Auxiliares |  | 27 |  |
| Megan Surprise | Auxiliares |  | 25 |  |
| Miguel Pattoni | Producción |  | 20.5 |  |
| Patricia López | Producción |  | 15 |  |
| Paúl Rodríguez | Producción |  | 28.12 |  |
| Reflector | Equipo |  |  |  |
| Ricardo Brenes | Producción |  | 18.5 |  |
| Salma Mitchell | Producción |  | 21 |  |
| Jeremy Alfaro | Producción |  | 22 |  |
| Susana Alfaro | Creativos |  | 15 |  |
| Teddy Bravo | Auxiliares |  | 18 |  |
| Alberto Bravo | Auxiliares |  | 18 |  |
| Catering | Gastos |  |  |  |
| Viáticos | Gastos |  |  |  |

## Schedule

| ID | WBS | Task | Type | Duration | Start | Finish | Predecessors | Complete | Remaining | Baseline start | Baseline finish | Baseline duration | Baseline 1 start | Baseline 1 finish | Total slack | Calendar | Resources | Work | Actual work | Cost | Baseline cost | Actual cost | Cast | Location |
| --- | --- | --- | --- | --- | --- | --- | --- | --- | --- | --- | --- | --- | --- | --- | --- | --- | --- | --- | --- | --- | --- | --- | --- | --- |
| 1 | 1 | **Preproducción** |  | 70d | 2016-03-07 A | 2016-06-10 A |  | 100% |  | 2016-03-07 | 2016-06-10 | 69.12d | 2016-03-07 | 2016-06-10 |  |  |  | 560h | 560h | 14,166.2 | 13,886 | 12,666.2 |  |  |
| 2 | 1.1 | Revisión del guión literario |  | 4d | 2016-03-07 A | 2016-03-10 A |  | 100% |  | 2016-03-07 | 2016-03-10 | 4d | 2016-03-07 | 2016-03-10 |  |  | Jeremy Alfaro | 32h | 32h | 704 | 704 | 704 |  |  |
| 3 | 1.2 | División y planificación del guión literario |  | 10d | 2016-03-11 A | 2016-03-24 A | 2 | 100% |  | 2016-03-11 | 2016-03-24 | 9d | 2016-03-11 | 2016-03-24 |  |  | Clara Blanco | 80h | 80h | 1,910 | 1,620 | 1,910 |  |  |
| 4 | 1.3 | Desarrollo del guión técnico |  | 1mo | 2016-03-25 A | 2016-04-21 A | 3 | 100% |  | 2016-03-24 | 2016-04-21 | 1mo | 2016-03-24 | 2016-04-21 |  |  | Jeremy Alfaro | 160h | 160h | 3,520 | 3,520 | 3,520 |  |  |
| 5 | 1.4 | Revisión del guión técnico |  | 1.2w | 2016-04-22 A | 2016-04-29 A | 4 | 100% |  | 2016-04-21 | 2016-04-28 | 1w | 2016-04-21 | 2016-04-28 |  |  | Clara Blanco | 48h | 48h | 1,146 | 900 | 1,146 |  |  |
| 6 | 1.5 | Búsqueda de exteriores |  | 2w | 2016-05-02 A | 2016-05-13 A | 5 | 100% |  | 2016-04-28 | 2016-05-12 | 2w | 2016-04-28 | 2016-05-12 |  |  | José Bolaños; Viáticos [0.1%] | 80h | 80h | 2,740 | 2,740 | 1,740 |  |  |
| 7 | 1.6 | Selección de exteriores |  | 1w | 2016-05-16 A | 2016-05-20 A | 6 | 100% |  | 2016-05-12 | 2016-05-19 | 1w | 2016-05-12 | 2016-05-19 |  |  | Jeremy Alfaro | 40h | 40h | 880 | 880 | 880 |  |  |
| 8 | 1.7 | Realización de pruebas a actores |  | 1d | 2016-05-23 A | 2016-05-23 A | 7 | 100% |  | 2016-05-19 | 2016-05-26 | 1w | 2016-05-19 | 2016-05-26 |  |  | Clara Blanco; Catering [0.1%] | 8h | 8h | 691 | 1,400 | 191 |  |  |
| 9 | 1.8 | Solicitud de permisos de rodaje |  | 1.2w | 2016-05-24 A | 2016-05-31 A | 8 | 100% |  | 2016-05-26 | 2016-06-02 | 1w | 2016-05-26 | 2016-06-02 |  |  | Kelly Borbón | 48h | 48h | 1,287.2 | 1,156 | 1,287.2 |  |  |
| 10 | 1.9 | Reserva de equipo de rodaje |  | 4d | 2016-06-01 A | 2016-06-06 A | 9 | 100% |  | 2016-06-02 | 2016-06-07 | 3d | 2016-06-02 | 2016-06-07 |  |  | Jenny Solera | 32h | 32h | 696 | 522 | 696 |  |  |
| 11 | 1.10 | Reserva de equipo de sonido |  | 4d | 2016-06-07 A | 2016-06-10 A | 10 | 100% |  | 2016-06-07 | 2016-06-10 | 3d | 2016-06-07 | 2016-06-10 |  |  | Erick Lagos | 32h | 32h | 592 | 444 | 592 |  |  |
| 12 | 1.11 | ¡Preproducción completada! | milestone | 0d | 2016-06-10 A | 2016-06-10 A | 11 | 100% |  | 2016-06-10 | 2016-06-10 | 0d | 2016-06-10 | 2016-06-10 |  |  |  |  |  |  |  |  |  |  |
| 13 | 2 | **Producción** |  | 27d | 2016-06-13 A | 2016-07-19 | 1 | 36% | 17.39d | 2016-06-10 | 2016-07-05 | 17.62d | 2016-06-10 | 2016-07-05 | 0d |  |  | 398h | 202h | 18,814.49 | 13,677.83 | 7,894 |  |  |
| 14 | 2.1 | **Escena 2** |  | 10d | 2016-06-13 A | 2016-06-25 A |  | 100% |  | 2016-06-10 | 2016-06-17 | 4.88d | 2016-06-10 | 2016-06-17 |  |  |  | 202h | 202h | 7,894 | 6,343.33 | 7,894 |  |  |
| 15 | 2.1.1 | Escena 2: Instalación de decorados |  | 2d | 2016-06-13 A | 2016-06-14 A |  | 100% |  | 2016-06-10 | 2016-06-13 | 1.5d | 2016-06-10 | 2016-06-13 |  |  | Electricista | 16h | 16h | 800 | 336 | 800 |  |  |
| 16 | 2.1.2 | Escena 2: Ensayo |  | 1d | 2016-06-15 A | 2016-06-15 A | 15 | 100% |  | 2016-06-13 | 2016-06-14 | 1d | 2016-06-13 | 2016-06-14 |  |  | Jenny Solera | 8h | 8h | 174 | 174 | 174 |  |  |
| 17 | 2.1.3 | Escena 2: Rodaje |  | 1.5d | 2016-06-16 A | 2016-06-17 A | 16 | 100% |  | 2016-06-14 | 2016-06-15 | 1.25d | 2016-06-14 | 2016-06-15 |  |  | Cámara de 16 mm [600%]; Foco de 500 watios [600%]; Megan Surprise; Trípode de cámara [600%]; Película de 16 mm [6 100 metros] | 138h | 138h | 4,920 | 1,260 | 4,920 | Richard, Store clerk #1, Store clerk #2 | Grocery store |
| 18 | 2.1.4 | Escena 2: Montaje |  | 5d | 2016-06-17 A | 2016-06-24 A | 17 | 100% |  | 2016-06-15 | 2016-06-16 | 0.75d | 2016-06-15 | 2016-06-16 |  |  | Electricista | 40h | 40h | 2,000 | 4,573.33 | 2,000 |  |  |
| 19 | 2.1.5 | Escena 2: Reproceso |  | 1d | 2016-06-24 A | 2016-06-25 A | 18 | 100% |  | 2016-06-16 | 2016-06-17 | 1d | 2016-06-16 | 2016-06-17 |  | Horario Nocturno |  |  |  |  |  |  |  |  |
| 20 | 2.2 | **Escena 3** |  | 9.5d | 2016-06-27 | 2016-07-08 | 14 |  |  | 2016-06-17 | 2016-06-27 | 7d | 2016-06-17 | 2016-06-27 | 0d |  |  | 118h |  | 6,577.99 | 3,785.99 |  |  |  |
| 21 | 2.2.1 | Escena 3: Instalación de decorados |  | 2d | 2016-06-27 | 2016-06-28 |  |  |  | 2016-06-17 | 2016-06-20 | 1.75d | 2016-06-17 | 2016-06-20 | 0d |  | Electricista | 16h |  | 800 | 392 |  |  |  |
| 22 | 2.2.2 | Escena 3: Ensayo |  | 1.75d | 2016-06-29 | 2016-06-30 | 21 |  |  | 2016-06-20 | 2016-06-22 | 1.75d | 2016-06-20 | 2016-06-22 | 0d |  | Jeremy Alfaro | 14h |  | 308 | 308 |  |  |  |
| 23 | 2.2.3 | Escena 3: Rodaje |  | 1.75d | 2016-06-30 | 2016-07-04 | 22 |  |  | 2016-06-22 | 2016-06-24 | 1.75d | 2016-06-22 | 2016-06-24 | 0d |  | Megan Surprise; Cámara de 16 mm; Foco de 500 watios; Trípode de cámara; Película de 16 mm [5.71 100 metros] | 56h |  | 3,869.99 | 2,693.99 |  | Man on street, Richard | Street corner |
| 24 | 2.2.4 | Escena 3: Montaje |  | 4d | 2016-07-04 | 2016-07-08 | 23 |  |  | 2016-06-24 | 2016-06-27 | 1.75d | 2016-06-24 | 2016-06-27 | 0d |  | Electricista | 32h |  | 1,600 | 392 |  |  |  |
| 25 | 2.2.5 | Escena 3: Reproceso |  | 1d | 2016-07-04 | 2016-07-05 | 23 |  |  | 2016-06-24 | 2016-06-25 | 1d | 2016-06-24 | 2016-06-25 | 3d | Horario Nocturno |  |  |  |  |  |  |  |  |

| ID | WBS | Task | Duration | Start | Finish | Predecessors | Baseline start | Baseline finish | Baseline duration | Baseline 1 start | Baseline 1 finish | Total slack | Calendar | Resources | Work | Cost | Baseline cost | Cast | Location |
| --- | --- | --- | --- | --- | --- | --- | --- | --- | --- | --- | --- | --- | --- | --- | --- | --- | --- | --- | --- |
| 26 | 2.3 | **Escena 1** | 7.5d | 2016-07-08 | 2016-07-19 | 20 | 2016-06-28 | 2016-07-05 | 5.75d | 2016-06-28 | 2016-07-05 | 0d |  |  | 78h | 4,342.5 | 3,548.5 |  |  |
| 27 | 2.3.1 | Escena 1: Instalación de decorados | 3d | 2016-07-08 | 2016-07-13 |  | 2016-06-28 | 2016-06-30 | 2.75d | 2016-06-28 | 2016-06-30 | 0d |  | Electricista | 24h | 1,200 | 616 |  |  |
| 28 | 2.3.2 | Escena 1: Ensayo | 0.75d | 2016-07-13 | 2016-07-14 | 27 | 2016-06-30 | 2016-07-01 | 0.75d | 2016-06-30 | 2016-07-01 | 0d |  | David Casas | 6h | 112.5 | 112.5 |  |  |
| 29 | 2.3.3 | Escena 1: Rodaje | 0.75d | 2016-07-14 | 2016-07-14 | 28 | 2016-07-01 | 2016-07-04 | 1.5d | 2016-07-01 | 2016-07-04 | 0d |  | Megan Surprise; Cámara de 16 mm; Foco de 500 watios; Trípode de cámara; Película de 16 mm [6.67 100 metros] | 24h | 1,830 | 2,652 | Garth, Man on street, Store clerk #1 | Street corner |
| 30 | 2.3.4 | Escena 1: Montaje | 3d | 2016-07-15 | 2016-07-19 | 29 | 2016-07-05 | 2016-07-05 | 0.75d | 2016-07-05 | 2016-07-05 | 0d |  | Electricista | 24h | 1,200 | 168 |  |  |
| 31 | 2.3.5 | Escena 1: Reproceso | 1d | 2016-07-14 | 2016-07-15 | 29 | 2016-07-04 | 2016-07-05 | 1d | 2016-07-04 | 2016-07-05 | 3d | Horario Nocturno |  |  |  |  |  |  |
| 32 | 3 | **Post-producción** | 68.25d | 2016-07-20 | 2016-10-24 | 13 | 2016-07-05 | 2016-10-07 | 68.25d | 2016-07-05 | 2016-10-07 | 0d |  |  | 1096h | 26,736.9 | 26,560.9 |  |  |
| 33 | 3.1 | Ajustes previos | 9d | 2016-07-20 | 2016-08-01 |  | 2016-07-05 | 2016-07-18 | 9d | 2016-07-05 | 2016-07-18 | 0d |  | Laboratorio de edición; Viáticos [0.2%]; Floría Víquez | 144h | 5,571 | 5,571 |  |  |
| 34 | 3.2 | Primera edición | 5d | 2016-08-02 | 2016-08-08 | 33 | 2016-07-18 | 2016-07-25 | 5d | 2016-07-18 | 2016-07-25 | 0d |  | Clara Blanco; Ricardo Brenes | 80h | 1,695 | 1,640 |  |  |
| 35 | 3.3 | Ajustes en la edición | 10d | 2016-08-09 | 2016-08-22 | 34 | 2016-07-25 | 2016-08-08 | 10d | 2016-07-25 | 2016-08-08 | 0d |  | Clara Blanco; Ricardo Brenes; Lisa Calero; Kelly Borbón; Laboratorio de edición | 400h | 8,507 | 8,397 |  |  |
| 36 | 3.4 | Presentación a cliente | 1d | 2016-08-23 | 2016-08-23 | 35 | 2016-08-08 | 2016-08-09 | 1d | 2016-08-08 | 2016-08-09 | 0d |  | Clara Blanco; José Bolaños; Mark O'hara [50%]; Jeremy Alfaro [50%]; Catering [0.6%] | 24h | 1,053 | 1,042 |  |  |
| 37 | 3.5 | Inserción banda sonora final | 9d | 2016-08-24 | 2016-09-05 | 36 | 2016-08-09 | 2016-08-22 | 9d | 2016-08-09 | 2016-08-22 | 0d |  | David Casas; Miguel Pattoni; Jeremy Alfaro | 216h | 4,410 | 4,410 |  |  |
| 38 | 3.6 | Adición de banda musical final | 16d | 2016-09-06 | 2016-09-27 | 37 | 2016-08-22 | 2016-09-13 | 16d | 2016-08-22 | 2016-09-13 | 0d |  | Miguel Pattoni | 128h | 2,624 | 2,624 |  |  |
| 39 | 3.7 | Impresión de negativos | 3d | 2016-09-28 | 2016-09-30 | 38 | 2016-09-13 | 2016-09-16 | 3d | 2016-09-13 | 2016-09-16 | 0d |  | Viáticos [0.2%]; Floría Víquez | 24h | 1,172 | 1,172 |  |  |
| 40 | 3.8 | Copia de la banda sonora final | 12d | 2016-10-03 | 2016-10-18 | 39 | 2016-09-16 | 2016-10-04 | 12d | 2016-09-16 | 2016-10-04 | 0d |  | Douglas Henao [50%] | 48h | 921.6 | 921.6 |  |  |
| 41 | 3.9 | Archivado de imagen y sonido finales | 2.25d | 2016-10-19 | 2016-10-21 | 40 | 2016-10-04 | 2016-10-06 | 2.25d | 2016-10-04 | 2016-10-06 | 0d |  | Douglas Henao [50%]; Laboratorio de edición; Miguel Pattoni | 24h | 619.3 | 619.3 |  |  |
| 42 | 3.10 | Entrega al distribuidor | 1d | 2016-10-21 | 2016-10-24 | 41 | 2016-10-07 | 2016-10-07 | 1d | 2016-10-07 | 2016-10-07 | 0d |  | Miguel Pattoni | 8h | 164 | 164 |  |  |
