# Breve proyecto cinematográfico

Schedule from MS Project, 2008-03-03 to 2008-12-17, costs in €, A marks actual dates.
Vídeos Southridge

## Calendars

- Evening Shoot: Mon-Fri 17:00-23:00; Sat-Sun off. Exceptions (off unless hours are given): 2008-07-04 (Independence Day), 2008-11-27 to 2008-11-28 (Thanksgiving 2008).
- Night Shift: Mon 23:00-24:00; Tue-Fri 00:00-03:00, 04:00-08:00, 23:00-24:00; Sat 00:00-03:00, 04:00-08:00; Sun off.
- Estándar: Mon-Fri 09:00-13:00, 15:00-19:00; Sat-Sun off.

## Resources

| Resource | Group | Unit | Rate | Cost per use |
| --- | --- | --- | --- | --- |
| Cámara de 16 mm | Equipo |  | 7.5 |  |
| Película de 16 mm | Material | 100 metros | 25 |  |
| Foco de 500 watios | Equipo |  | 2.5 |  |
| Anne L. Paper | Creativos |  | 18.75 |  |
| Trípode de cámara | Equipo |  |  |  |
| Clair Hector | Producción |  | 22.5 |  |
| Grúa | Equipo |  |  |  |
| Daniel Penn | Creativos |  | 18.75 |  |
| David Campbell | Creativos |  | 18.75 |  |
| Dolly | Equipo |  |  |  |
| Doug Hampton | Producción |  | 16 |  |
| Laboratorio de edición | Equipo |  | 31.25 | 25 |
| Electricista | Auxiliares |  | 28 |  |
| Eric Lang | Producción |  | 18.5 |  |
| Eric Miller | Creativos |  | 18.75 |  |
| Florian Voss | Producción |  | 25 |  |
| Frank Lee | Auxiliares |  | 17 |  |
| Jan Miksovsky | Producción |  | 21.75 |  |
| Jim Hance | Creativos |  | 9.38 |  |
| Jo Brown | Producción |  | 21.75 |  |
| Johnathan Perrera | Producción |  | 25 |  |
| Joseph Matthews | Creativos |  | 18.75 |  |
| Joshua Randall | Creativos |  | 16 |  |
| Kathryn Wilson | Producción |  | 20 | 100 |
| Keith Harris | Auxiliares |  | 17 |  |
| Kim Yoshida | Production |  | 16.4 |  |
| Linda Kobara | Producción |  | 27 |  |
| Lisa Garmaise | Producción |  | 16 |  |
| Mark Hassall | Producción |  | 25 |  |
| Max Benson | Auxiliares |  | 27 |  |
| Megan Sherman | Auxiliares |  | 21 |  |
| Michael Patten | Producción |  | 20.5 |  |
| Pat Kirtland | Producción |  | 15 |  |
| Paul Borm | Producción |  | 28.12 |  |
| Reflector | Equipo |  |  |  |
| Richard Lum | Producción |  | 18.5 |  |
| Salman Mughal | Producción |  | 21 |  |
| Scott Cooper | Producción |  | 22 |  |
| Sue Jackson | Creativos |  | 15 |  |
| Ted Bremer | Auxiliares |  | 18 |  |
| Tim O'Brien | Auxiliares |  | 18 |  |
| Catering | Gastos |  |  |  |
| Viajes | Gastos |  |  |  |

## Schedule

| ID | WBS | Task | Type | Duration | Start | Finish | Predecessors | Complete | Remaining | Baseline start | Baseline finish | Baseline duration | Total slack | Constraint | Deadline | Calendar | Resources | Work | Actual work | Cost | Baseline cost | Actual cost | Cast | Location |
| --- | --- | --- | --- | --- | --- | --- | --- | --- | --- | --- | --- | --- | --- | --- | --- | --- | --- | --- | --- | --- | --- | --- | --- | --- |
| 1 | 1 | **Preproducción** |  | 59.75d | 2008-03-03 A | 2008-05-23 A |  | 100% |  | 2008-03-03 | 2008-05-27 | 61.75d |  |  |  |  |  | 1305h | 1305h | 30,672.06 | 33,840 | 29,172.06 |  |  |
| 2 | 1.1 | Revisión del guión literario |  | 3.75d | 2008-03-03 A | 2008-03-06 A |  | 100% |  | 2008-03-03 | 2008-03-06 | 4d |  |  |  |  | Scott Cooper [53.3%]; Clair Hector [106.7%] | 40h | 40h | 892 | 892 | 892 |  |  |
| 3 | 1.2 | División y planificación del guión literario |  | 6.51d | 2008-03-07 A | 2008-03-17 A | 2 | 100% |  | 2008-03-07 | 2008-03-17 | 6d |  |  |  |  | Scott Cooper [158.3%]; Johnathan Perrera [158.3%]; Clair Hector [156.8%] | 151h | 151h | 3,497.5 | 3,336 | 3,497.5 |  |  |
| 4 | 1.3 | Desarrollo del guión técnico |  | 0.89mo | 2008-03-18 A | 2008-04-10 A | 3 | 100% |  | 2008-03-17 | 2008-04-15 | 1mo |  |  |  |  | Scott Cooper [152.1%]; Kim Yoshida [152.1%]; Johnathan Perrera [152.1%] | 454h | 454h | 9,558.56 | 12,398 | 9,558.56 |  |  |
| 5 | 1.4 | Revisión del guión técnico |  | 0.95w | 2008-04-11 A | 2008-04-17 A | 4 | 100% |  | 2008-04-15 | 2008-04-22 | 1w |  |  |  |  | Clair Hector [105.3%]; Scott Cooper [105.3%] | 80h | 80h | 1,780 | 1,780 | 1,780 |  |  |
| 6 | 1.5 | Búsqueda de exteriores |  | 1.75w | 2008-04-18 A | 2008-04-30 A | 5 | 100% |  | 2008-04-22 | 2008-05-06 | 2w |  |  |  |  | Jo Brown [102.9%]; Jan Miksovsky [102.9%]; Max Benson [102.9%]; Viajes [0.1%] | 216h | 216h | 6,076 | 6,640 | 5,076 |  |  |
| 7 | 1.6 | Selección de exteriores |  | 0.95w | 2008-05-02 A | 2008-05-08 A | 6 | 100% |  | 2008-05-06 | 2008-05-13 | 1w |  |  |  |  | Scott Cooper [105.6%]; Clair Hector [105.6%]; Max Benson [105.3%] | 116h | 116h | 2,771 | 2,771 | 2,771 |  |  |
| 8 | 1.7 | Realización de pruebas a actores |  | 0.95w | 2008-05-09 A | 2008-05-15 A | 7 | 100% |  | 2008-05-13 | 2008-05-20 | 1w |  |  |  |  | Clair Hector [105.6%]; Scott Cooper [105.6%]; Doug Hampton [52.6%]; Catering [0.1%] | 96h | 96h | 2,511 | 2,511 | 2,011 |  |  |
| 9 | 1.8 | Solicitud de permisos de rodaje |  | 0.95w | 2008-05-16 A | 2008-05-22 A | 8 | 100% |  | 2008-05-20 | 2008-05-27 | 1w |  |  |  |  | Kim Yoshida [105.3%] | 40h | 40h | 1,156 | 1,156 | 1,156 |  |  |
| 10 | 1.9 | Reserva de equipo de rodaje |  | 2.88d | 2008-05-20 A | 2008-05-23 A | 9FS-5% | 100% |  | 2008-05-22 | 2008-05-27 | 3d |  |  |  |  | Jan Miksovsky [104.3%]; Eric Lang [52.2%] | 36h | 36h | 744 | 744 | 744 |  |  |
| 11 | 1.10 | Reserva de equipo de sonido |  | 3.25d | 2008-05-20 A | 2008-05-23 A | 10SS | 100% |  | 2008-05-22 | 2008-05-27 | 3d |  |  |  |  | Eric Lang [80.8%] | 16h | 16h | 296 | 222 | 296 |  |  |
| 12 | 1.11 | ¡Preproducción completada! | milestone | 0d | 2008-05-23 A | 2008-05-23 A | 11 | 100% |  | 2008-05-27 | 2008-05-27 | 0d |  |  | 2008-05-22 |  |  |  |  |  |  |  |  |  |
| 13 | 1.12 | **Reunión de seguimiento** |  | 45.12d | 2008-03-10 A | 2008-05-12 A |  | 100% |  | 2008-03-10 | 2008-05-12 | 45.25d |  |  |  |  |  | 60h | 60h | 1,390 | 1,390 | 1,390 |  |  |
| 14 | 1.12.1 | Reunión de seguimiento 1 |  | 1h | 2008-03-10 A | 2008-03-10 A |  | 100% |  | 2008-03-10 | 2008-03-10 | 2h |  | start no earlier than 2008-03-10 |  |  | Clair Hector [200%]; Johnathan Perrera [200%]; Scott Cooper [200%] | 6h | 6h | 139 | 139 | 139 |  |  |
| 15 | 1.12.2 | Reunión de seguimiento 2 |  | 1h | 2008-03-17 A | 2008-03-17 A |  | 100% |  | 2008-03-17 | 2008-03-17 | 2h |  | start no earlier than 2008-03-17 |  |  | Clair Hector [200%]; Johnathan Perrera [200%]; Scott Cooper [200%] | 6h | 6h | 139 | 139 | 139 |  |  |
| 16 | 1.12.3 | Reunión de seguimiento 3 |  | 1h | 2008-03-24 A | 2008-03-24 A |  | 100% |  | 2008-03-24 | 2008-03-24 | 2h |  | start no earlier than 2008-03-24 |  |  | Clair Hector [200%]; Johnathan Perrera [200%]; Scott Cooper [200%] | 6h | 6h | 139 | 139 | 139 |  |  |
| 17 | 1.12.4 | Reunión de seguimiento 4 |  | 1h | 2008-03-31 A | 2008-03-31 A |  | 100% |  | 2008-03-31 | 2008-03-31 | 2h |  | start no earlier than 2008-03-31 |  |  | Clair Hector [200%]; Johnathan Perrera [200%]; Scott Cooper [200%] | 6h | 6h | 139 | 139 | 139 |  |  |
| 18 | 1.12.5 | Reunión de seguimiento 5 |  | 1h | 2008-04-07 A | 2008-04-07 A |  | 100% |  | 2008-04-07 | 2008-04-07 | 2h |  | start no earlier than 2008-04-07 |  |  | Clair Hector [200%]; Johnathan Perrera [200%]; Scott Cooper [200%] | 6h | 6h | 139 | 139 | 139 |  |  |
| 19 | 1.12.6 | Reunión de seguimiento 6 |  | 1h | 2008-04-14 A | 2008-04-14 A |  | 100% |  | 2008-04-14 | 2008-04-14 | 2h |  | start no earlier than 2008-04-14 |  |  | Clair Hector [200%]; Johnathan Perrera [200%]; Scott Cooper [200%] | 6h | 6h | 139 | 139 | 139 |  |  |
| 20 | 1.12.7 | Reunión de seguimiento 7 |  | 1h | 2008-04-21 A | 2008-04-21 A |  | 100% |  | 2008-04-21 | 2008-04-21 | 2h |  | start no earlier than 2008-04-21 |  |  | Clair Hector [200%]; Johnathan Perrera [200%]; Scott Cooper [200%] | 6h | 6h | 139 | 139 | 139 |  |  |
| 21 | 1.12.8 | Reunión de seguimiento 8 |  | 1h | 2008-04-28 A | 2008-04-28 A |  | 100% |  | 2008-04-28 | 2008-04-28 | 2h |  | start no earlier than 2008-04-28 |  |  | Clair Hector [200%]; Johnathan Perrera [200%]; Scott Cooper [200%] | 6h | 6h | 139 | 139 | 139 |  |  |
| 22 | 1.12.9 | Reunión de seguimiento 9 |  | 1h | 2008-05-05 A | 2008-05-05 A |  | 100% |  | 2008-05-05 | 2008-05-05 | 2h |  | start no earlier than 2008-05-05 |  |  | Clair Hector [200%]; Johnathan Perrera [200%]; Scott Cooper [200%] | 6h | 6h | 139 | 139 | 139 |  |  |
| 23 | 1.12.10 | Reunión de seguimiento 10 |  | 1h | 2008-05-12 A | 2008-05-12 A |  | 100% |  | 2008-05-12 | 2008-05-12 | 2h |  | start no earlier than 2008-05-12 |  |  | Clair Hector [200%]; Johnathan Perrera [200%]; Scott Cooper [200%] | 6h | 6h | 139 | 139 | 139 |  |  |
| 24 | 2 | **Producción** |  | 52d | 2008-05-26 A | 2008-08-06 | 1 | 39% | 31.72d | 2008-05-27 | 2008-08-06 | 49.25d | 0d |  | 2008-08-08 |  |  | 2914h | 1231h | 59,997.35 | 54,034 | 24,931.25 |  |  |
| 25 | 2.1 | **Escena 7** |  | 5d | 2008-05-26 A | 2008-05-31 A |  | 100% |  | 2008-05-27 | 2008-06-03 | 4.25d |  |  |  |  |  | 351h | 351h | 6,394.25 | 4,718.5 | 6,394.25 |  |  |
| 26 | 2.1.1 | Escena 7: Instalación de decorados |  | 1.5d | 2008-05-26 A | 2008-05-27 A |  | 100% |  | 2008-05-27 | 2008-05-28 | 1d |  |  |  |  | Jo Brown [116.7%]; Max Benson [116.7%]; Electricista [58.3%] | 20h | 20h | 502 | 502 | 502 |  |  |
| 27 | 2.1.2 | Escena 7: Ensayo |  | 1d | 2008-05-27 A | 2008-05-28 A | 26 | 100% |  | 2008-05-28 | 2008-05-29 | 1d |  |  |  |  | Scott Cooper [200%]; Jo Brown [150%]; Paul Borm [150%]; Joseph Matthews [116.7%]; Sue Jackson; Jan Miksovsky [150%] | 49h | 49h | 1,013.25 | 906.5 | 1,013.25 |  |  |
| 28 | 2.1.3 | Escena 7: Rodaje |  | 1.25d | 2008-05-28 A | 2008-05-29 A | 27 | 100% |  | 2008-05-29 | 2008-05-30 | 1d |  |  |  |  | Scott Cooper [600%]; Jo Brown [600%]; Joseph Matthews [600%]; Sue Jackson [600%]; Frank Lee [600%]; Keith Harris [600%]; Ted Bremer; Cámara de 16 mm [600%]; Foco de 500 watios [600%]; Joshua Randall [600%]; Megan Sherman [600%]; Tim O'Brien; Jan Miksovsky [600%]; Trípode de cámara [600%]; Película de 16 mm [6 100 metros] | 256h | 256h | 4,238 | 2,808 | 4,238 | Richard, Store clerk #1, Store clerk #2 | Grocery store |
| 29 | 2.1.4 | Escena 7: Montaje |  | 0.75d | 2008-05-30 A | 2008-05-30 A | 28 | 100% |  | 2008-05-30 | 2008-06-02 | 1d |  |  |  |  | Jo Brown [200%]; Max Benson [200%]; Electricista [33.3%] | 26h | 26h | 641 | 502 | 641 |  |  |
| 30 | 2.1.5 | Escena 7: Reproceso |  | 1d | 2008-05-30 A | 2008-05-31 A | 29 | 100% |  | 2008-06-02 | 2008-06-03 | 1d |  |  |  | Night Shift |  |  |  |  |  |  |  |  |

| ID | WBS | Task | Duration | Start | Finish | Predecessors | Complete | Remaining | Baseline start | Baseline finish | Baseline duration | Total slack | Free slack | Constraint | Calendar | Resources | Work | Actual work | Cost | Baseline cost | Actual cost | Cast | Location |
| --- | --- | --- | --- | --- | --- | --- | --- | --- | --- | --- | --- | --- | --- | --- | --- | --- | --- | --- | --- | --- | --- | --- | --- |
| 31 | 2.2 | **Escena 3** | 8.75d | 2008-06-02 A | 2008-06-12 A | 25 | 100% |  | 2008-06-03 | 2008-06-06 | 4d |  |  |  |  |  | 532h | 532h | 10,466 | 5,318 | 10,466 |  |  |
| 32 | 2.2.1 | Escena 3: Instalación de decorados | 2.75d | 2008-06-02 A | 2008-06-04 A |  | 100% |  | 2008-06-03 | 2008-06-03 | 1d |  |  | start no earlier than 2008-05-26 |  | Jo Brown [222.2%]; Max Benson [222.2%]; Electricista [54.5%] | 54h | 54h | 1,338 | 614 | 1,338 |  |  |
| 33 | 2.2.2 | Escena 3: Ensayo | 1.75d | 2008-06-05 A | 2008-06-06 A | 32 | 100% |  | 2008-06-04 | 2008-06-04 | 1d |  |  |  |  | Scott Cooper [114.3%]; Jo Brown [114.3%]; Eric Miller [114.3%]; Jim Hance [114.3%]; Anne L. Paper [114.3%]; Joseph Matthews [114.3%]; Jan Miksovsky [114.3%] | 112h | 112h | 2,098 | 1,049 | 2,098 |  |  |
| 34 | 2.2.3 | Escena 3: Rodaje | 1.75d | 2008-06-09 A | 2008-06-10 A | 33 | 100% |  | 2008-06-05 | 2008-06-05 | 1d |  |  |  |  | Scott Cooper [114.3%]; Jo Brown [114.3%]; Eric Miller [114.3%]; Jim Hance [114.3%]; Anne L. Paper [114.3%]; Joseph Matthews [114.3%]; Tim O'Brien [114.3%]; Megan Sherman [114.3%]; Doug Hampton [57.1%]; Keith Harris [114.3%]; Cámara de 16 mm [228.6%]; Foco de 500 watios [457.1%]; Dolly [114.3%]; Frank Lee [114.3%]; Jan Miksovsky [114.3%]; Ted Bremer [114.3%]; Trípode de cámara [114.3%]; Película de 16 mm [5.71 100 metros] | 328h | 328h | 6,082 | 3,041 | 6,082 | Man on street, Richard | Street corner |
| 35 | 2.2.4 | Escena 3: Montaje | 1.75d | 2008-06-11 A | 2008-06-12 A | 34 | 100% |  | 2008-06-06 | 2008-06-06 | 1d |  |  |  |  | Jo Brown [218.2%]; Max Benson [218.2%]; Electricista [57.1%] | 38h | 38h | 948 | 614 | 948 |  |  |
| 36 | 2.2.5 | Escena 3: Reproceso | 1d | 2008-06-10 A | 2008-06-11 A | 34 | 100% |  | 2008-06-05 | 2008-06-06 | 1d |  |  |  | Night Shift |  |  |  |  |  |  |  |  |
| 37 | 2.3 | **Escena 1** | 7.75d | 2008-06-13 A | 2008-06-24 A | 31 | 100% |  | 2008-06-09 | 2008-06-16 | 6d |  |  |  |  |  | 324h | 324h | 7,457 | 7,457 | 7,457 |  |  |
| 38 | 2.3.1 | Escena 1: Instalación de decorados | 2.75d | 2008-06-13 A | 2008-06-19 A |  | 100% |  | 2008-06-09 | 2008-06-11 | 3d |  |  |  |  | Jo Brown [109.1%]; Max Benson [109.1%]; Electricista [218.2%] | 96h | 96h | 2,514 | 2,514 | 2,514 |  |  |
| 39 | 2.3.2 | Escena 1: Ensayo | 0.75d | 2008-06-20 A | 2008-06-20 A | 38 | 100% |  | 2008-06-12 | 2008-06-12 | 1d |  |  |  |  | Scott Cooper [133.3%]; Jo Brown [133.3%]; Paul Borm [66.7%]; David Campbell [133.3%]; Eric Miller [133.3%]; Sue Jackson [133.3%]; Jan Miksovsky [133.3%] | 52h | 52h | 1,056.5 | 1,056.5 | 1,056.5 |  |  |
| 40 | 2.3.3 | Escena 1: Rodaje | 0.75d | 2008-06-23 A | 2008-06-23 A | 39 | 100% |  | 2008-06-13 | 2008-06-13 | 1d |  |  |  |  | Scott Cooper [133.3%]; Jo Brown [133.3%]; Paul Borm [66.7%]; David Campbell [133.3%]; Eric Miller [133.3%]; Sue Jackson [133.3%]; Tim O'Brien [133.3%]; Frank Lee [133.3%]; Megan Sherman [133.3%]; Doug Hampton [66.7%]; Keith Harris [133.3%]; Ted Bremer [133.3%]; Cámara de 16 mm [400%]; Foco de 500 watios [133.3%]; Jan Miksovsky [133.3%]; Dolly [133.3%]; Trípode de cámara [133.3%]; Película de 16 mm [6.67 100 metros] | 144h | 144h | 3,048.5 | 3,048.5 | 3,048.5 | Garth, Man on street, Store clerk #1 | Street corner |
| 41 | 2.3.4 | Escena 1: Montaje | 0.75d | 2008-06-24 A | 2008-06-24 A | 40 | 100% |  | 2008-06-16 | 2008-06-16 | 1d |  |  |  |  | Jo Brown [133.3%]; Max Benson [133.3%]; Electricista [266.7%] | 32h | 32h | 838 | 838 | 838 |  |  |
| 42 | 2.3.5 | Escena 1: Reproceso | 1d | 2008-06-23 A | 2008-06-24 A | 40 | 100% |  | 2008-06-13 | 2008-06-14 | 1d |  |  |  | Night Shift |  |  |  |  |  |  |  |  |
| 43 | 2.4 | **Escena 2** | 5d | 2008-06-25 A | 2008-07-02 | 37 | 13% | 4.35d | 2008-06-17 | 2008-06-21 | 4d | 0d |  |  |  |  | 240h | 24h | 5,035.6 | 4,396 | 614 |  |  |
| 44 | 2.4.1 | Escena 2: Instalación de decorados | 1.75d | 2008-06-25 A | 2008-06-26 |  | 43% | 1d | 2008-06-17 | 2008-06-17 | 1d | 0.25d | 0d |  |  | Jo Brown [133.3%]; Max Benson [133.3%]; Electricista [133.3%] | 48h | 24h | 1,228 | 614 | 614 |  |  |
| 45 | 2.4.2 | Escena 2: Ensayo | 1d | 2008-06-26 | 2008-06-27 | 44 |  |  | 2008-06-18 | 2008-06-18 | 1d | 0.25d | 0d |  |  | Scott Cooper; Doug Hampton [50%]; David Campbell; Anne L. Paper; Jan Miksovsky | 36h |  | 726.8 | 714 |  |  |  |
| 46 | 2.4.3 | Escena 2: Rodaje | 1d | 2008-06-27 | 2008-06-30 | 45 |  |  | 2008-06-18 | 2008-06-19 | 1d | 0.5d | 0d |  | Evening Shoot | Scott Cooper; Doug Hampton [50%]; Anne L. Paper; Tim O'Brien; Frank Lee; Keith Harris; Ted Bremer; Cámara de 16 mm [200%]; Foco de 500 watios [300%]; Jan Miksovsky; David Campbell; Trípode de cámara; Grúa; Dolly; Película de 16 mm [5 100 metros] | 132h |  | 2,466.8 | 2,454 |  | Garth, Shelly | Shelly's living room |
| 47 | 2.4.4 | Escena 2: Montaje | 1d | 2008-07-01 | 2008-07-01 | 46 |  |  | 2008-06-20 | 2008-06-20 | 1d | 0d |  |  |  | Jo Brown; Max Benson; Electricista | 24h |  | 614 | 614 |  |  |  |
| 48 | 2.4.5 | Escena 2: Reproceso | 1d | 2008-07-01 | 2008-07-02 | 47 |  |  | 2008-06-20 | 2008-06-21 | 1d | 0d |  |  | Night Shift |  |  |  |  |  |  |  |  |
| 49 | 2.5 | **Escena 5** | 5d | 2008-07-02 | 2008-07-08 | 43 |  |  | 2008-06-23 | 2008-06-30 | 6d | 0.2d | 0d |  |  |  | 352h |  | 7,423.8 | 7,717.8 |  |  |  |
| 50 | 2.5.1 | Escena 5: Instalación de decorados | 2d | 2008-07-02 | 2008-07-03 |  |  |  | 2008-06-23 | 2008-06-25 | 3d | 0.2d | 0d |  |  | Jo Brown; Max Benson; Electricista [200%]; Frank Lee; Keith Harris | 96h |  | 2,220 | 2,514 |  |  |  |
| 51 | 2.5.2 | Escena 5: Ensayo | 1d | 2008-07-04 | 2008-07-04 | 50 |  |  | 2008-06-26 | 2008-06-26 | 1d | 0.2d | 0d |  |  | Scott Cooper; Jo Brown; Eric Miller; David Campbell; Sue Jackson; Daniel Penn; Anne L. Paper; Jan Miksovsky [50%] | 60h |  | 1,157 | 1,157 |  |  |  |
| 52 | 2.5.3 | Escena 5: Rodaje | 1d | 2008-07-07 | 2008-07-07 | 51 |  |  | 2008-06-27 | 2008-06-27 | 1d | 0.2d | 0d |  |  | Scott Cooper; Jo Brown; Eric Miller; David Campbell; Sue Jackson; Daniel Penn; Anne L. Paper; Tim O'Brien; Frank Lee; Megan Sherman; Doug Hampton [50%]; Keith Harris; Ted Bremer; Cámara de 16 mm [200%]; Foco de 500 watios [200%]; Grúa; Jan Miksovsky; Trípode de cámara; Dolly; Película de 16 mm [5 100 metros] | 164h |  | 3,208.8 | 3,208.8 |  | Man on street, Garth, Old man, Shelly | Street corner |
| 53 | 2.5.4 | Escena 5: Montaje | 1d | 2008-07-08 | 2008-07-08 | 52 |  |  | 2008-06-30 | 2008-06-30 | 1d | 0.2d |  |  |  | Jo Brown; Max Benson; Electricista [200%] | 32h |  | 838 | 838 |  |  |  |
| 54 | 2.5.5 | Escena 5: Reproceso | 1d | 2008-07-07 | 2008-07-08 | 52 |  |  | 2008-06-27 | 2008-06-28 | 1d | 1d |  |  | Night Shift |  |  |  |  |  |  |  |  |

| ID | WBS | Task | Duration | Start | Finish | Predecessors | Baseline start | Baseline finish | Baseline duration | Total slack | Free slack | Calendar | Resources | Work | Cost | Baseline cost | Cast | Location |
| --- | --- | --- | --- | --- | --- | --- | --- | --- | --- | --- | --- | --- | --- | --- | --- | --- | --- | --- |
| 55 | 2.6 | **Escena 6** | 10d | 2008-07-09 | 2008-07-23 | 49 | 2008-07-01 | 2008-07-19 | 13d | 0d |  |  |  | 644h | 13,129 | 13,964.2 |  |  |
| 56 | 2.6.1 | Escena 6: Instalación de decorados | 4d | 2008-07-09 | 2008-07-14 |  | 2008-07-01 | 2008-07-09 | 6d | 0.2d | 0d |  | Jo Brown; Max Benson; Electricista [200%]; Frank Lee; Keith Harris | 192h | 4,440 | 5,028 |  |  |
| 57 | 2.6.2 | Escena 6: Ensayo | 3d | 2008-07-15 | 2008-07-17 | 56 | 2008-07-10 | 2008-07-14 | 3d | 0.2d | 0d |  | Scott Cooper; Jo Brown; Doug Hampton [50%]; Paul Borm [50%]; David Campbell; Sue Jackson; Anne L. Paper; Jim Hance; Daniel Penn; Jan Miksovsky [50%] | 204h | 3,813.9 | 3,813.9 |  |  |
| 58 | 2.6.3 | Escena 6: Rodaje | 1d | 2008-07-18 | 2008-07-18 | 57 | 2008-07-15 | 2008-07-15 | 1d | 0.2d | 0d |  | Scott Cooper; Jo Brown; Doug Hampton [50%]; Paul Borm [50%]; David Campbell; Sue Jackson; Anne L. Paper; Jim Hance; Daniel Penn; Frank Lee; Megan Sherman; Keith Harris; Ted Bremer; Cámara de 16 mm [300%]; Foco de 500 watios [300%]; Dolly; Grúa; Joshua Randall; Tim O'Brien; Película de 16 mm [5 100 metros] | 176h | 3,280.3 | 3,280.3 | Garth, Store Clerk #1, Shelly, Old man | Grocery store |
| 59 | 2.6.4 | Escena 6: Montaje | 1.8d | 2008-07-21 | 2008-07-22 | 58 | 2008-07-16 | 2008-07-18 | 3d | 0.2d |  |  | Jo Brown; Max Benson; Electricista; Frank Lee; Keith Harris | 72h | 1,594.8 | 1,842 |  |  |
| 60 | 2.6.5 | Escena 6: Reproceso | 1d | 2008-07-22 | 2008-07-23 | 59 | 2008-07-18 | 2008-07-19 | 1d | 0d |  | Night Shift |  |  |  |  |  |  |
| 61 | 2.7 | **Escena 8** | 6d | 2008-07-23 | 2008-07-31 | 55 | 2008-07-21 | 2008-07-31 | 8d | 0d |  |  |  | 356h | 7,312.1 | 7,682.9 |  |  |
| 62 | 2.7.1 | Escena 8: Instalación de decorados | 1.8d | 2008-07-23 | 2008-07-24 |  | 2008-07-21 | 2008-07-23 | 3d | 0.3d | 0d |  | Jo Brown; Max Benson; Electricista; Frank Lee; Keith Harris | 72h | 1,594.8 | 1,842 |  |  |
| 63 | 2.7.2 | Escena 8: Ensayo | 2d | 2008-07-24 | 2008-07-28 | 62 | 2008-07-24 | 2008-07-25 | 2d | 0.3d | 0d |  | Scott Cooper; Jo Brown; Doug Hampton [50%]; Paul Borm [50%]; David Campbell; Sue Jackson; Eric Miller; Jan Miksovsky [50%] | 104h | 2,092.6 | 2,092.6 |  |  |
| 64 | 2.7.3 | Escena 8: Rodaje | 1d | 2008-07-28 | 2008-07-29 | 63 | 2008-07-28 | 2008-07-28 | 1d | 0.3d | 0d |  | Scott Cooper; Jo Brown; Doug Hampton [50%]; Paul Borm [50%]; David Campbell; Sue Jackson; Eric Miller; Tim O'Brien; Frank Lee; Megan Sherman; Keith Harris; Ted Bremer; Cámara de 16 mm [200%]; Foco de 500 watios; Dolly [200%]; Trípode de cámara; Grúa; Película de 16 mm [5 100 metros] | 144h | 2,827.3 | 2,827.3 | Garth, Store clerk #1, Man on street | Street corner |
| 65 | 2.7.4 | Escena 8: Montaje | 0.9d | 2008-07-29 | 2008-07-30 | 64 | 2008-07-29 | 2008-07-30 | 1.5d | 0.3d |  |  | Jo Brown; Max Benson; Electricista; Frank Lee; Keith Harris | 36h | 797.4 | 921 |  |  |
| 66 | 2.7.5 | Escena 8: Reproceso | 1d | 2008-07-30 | 2008-07-31 | 65 | 2008-07-30 | 2008-07-31 | 1d | 0d |  | Night Shift |  |  |  |  |  |  |
| 67 | 2.8 | **Escena 4** | 4d | 2008-07-31 | 2008-08-06 | 61 | 2008-07-31 | 2008-08-06 | 4d | 0d |  |  |  | 115h | 2,779.6 | 2,779.6 |  |  |
| 68 | 2.8.1 | Escena 4: Instalación de decorados | 1.5d | 2008-07-31 | 2008-08-01 |  | 2008-07-31 | 2008-08-01 | 1.5d | 0.25d | 0d |  | Jo Brown; Max Benson; Electricista | 36h | 921 | 921 |  |  |
| 69 | 2.8.2 | Escena 4: Ensayo | 4h | 2008-08-01 | 2008-08-01 | 68 | 2008-08-01 | 2008-08-01 | 4h | 0.25d | 0d |  | Scott Cooper; Doug Hampton [50%]; Anne L. Paper; Joseph Matthews; Jan Miksovsky [50%] | 16h | 319.9 | 319.9 |  |  |
| 70 | 2.8.3 | Escena 4: Rodaje | 2h | 2008-08-04 | 2008-08-04 | 69 | 2008-08-04 | 2008-08-04 | 2h | 0.25d | 0d |  | Scott Cooper; Doug Hampton [50%]; Anne L. Paper; Joseph Matthews; Frank Lee; Megan Sherman; Keith Harris; Cámara de 16 mm [200%]; Foco de 500 watios [200%]; Jan Miksovsky; Ted Bremer; Trípode de cámara; Película de 16 mm [5 100 metros] | 27h | 617.7 | 617.7 | Shelly, Richard | Elevator |
| 71 | 2.8.4 | Escena 4: Montaje | 1.5d | 2008-08-04 | 2008-08-05 | 70 | 2008-08-04 | 2008-08-05 | 1.5d | 0.25d |  |  | Jo Brown; Max Benson; Electricista | 36h | 921 | 921 |  |  |
| 72 | 2.8.5 | Escena 4: Reproceso | 1d | 2008-08-05 | 2008-08-06 | 71 | 2008-08-05 | 2008-08-06 | 1d | 0d |  | Night Shift |  |  |  |  |  |  |
| 73 | 3 | **Post-producción** | 95.25d | 2008-08-06 | 2008-12-17 | 24 | 2008-08-06 | 2008-12-19 | 95.25d | 0d |  |  |  | 1724h | 39,062.4 | 36,662.4 |  |  |
| 74 | 3.1 | Ajustes previos | 9d | 2008-08-06 | 2008-08-18 |  | 2008-08-06 | 2008-08-18 | 9d | 0d |  |  | Laboratorio de edición; Viajes [0.2%]; Florian Voss | 144h | 5,571 | 3,771 |  |  |
| 75 | 3.2 | Grabación BS previa | 12d | 2008-08-19 | 2008-09-03 | 74 | 2008-08-19 | 2008-09-03 | 12d | 0d |  |  | David Campbell; Michael Patten | 192h | 3,768 | 3,768 |  |  |
| 76 | 3.3 | Edición en papel | 10d | 2008-09-04 | 2008-09-17 | 75 | 2008-09-04 | 2008-09-17 | 10d | 0d |  |  | Clair Hector; Kim Yoshida; Lisa Garmaise; Richard Lum | 320h | 5,872 | 5,872 |  |  |
| 77 | 3.4 | Primera edición | 5d | 2008-09-18 | 2008-09-24 | 76 | 2008-09-18 | 2008-09-24 | 5d | 0d |  |  | Clair Hector; Richard Lum | 80h | 1,640 | 1,640 |  |  |
| 78 | 3.5 | Ajustes en la edición | 10d | 2008-09-25 | 2008-10-08 | 77 | 2008-09-25 | 2008-10-08 | 10d | 0d |  |  | Clair Hector; Richard Lum; Lisa Garmaise; Kim Yoshida; Laboratorio de edición | 400h | 8,397 | 8,397 |  |  |
| 79 | 3.6 | Presentación a cliente | 1d | 2008-10-09 | 2008-10-09 | 78 | 2008-10-09 | 2008-10-09 | 1d | 0d |  |  | Clair Hector; Jo Brown; Mark Hassall [50%]; Scott Cooper [50%]; Catering [0.6%] | 24h | 1,042 | 1,042 |  |  |
| 80 | 3.7 | Inserción banda sonora final | 9d | 2008-10-10 | 2008-10-22 | 79 | 2008-10-10 | 2008-10-22 | 9d | 0d |  |  | David Campbell; Michael Patten; Scott Cooper | 216h | 4,410 | 4,410 |  |  |
| 81 | 3.8 | Adición de cabeceras y créditos | 1w | 2008-10-23 | 2008-10-29 | 80 | 2008-10-23 | 2008-10-29 | 1w | 0d |  |  | Jo Brown; Michael Patten; Laboratorio de edición | 120h | 2,965 | 2,965 |  |  |
| 82 | 3.9 | Adición de banda musical final | 16d | 2008-10-30 | 2008-11-20 | 81 | 2008-10-30 | 2008-11-20 | 16d | 0d |  |  | Michael Patten | 128h | 2,624 | 2,624 |  |  |
| 83 | 3.10 | Impresión de negativos | 3d | 2008-11-21 | 2008-11-25 | 82 | 2008-11-21 | 2008-11-25 | 3d | 0d |  |  | Viajes [0.2%]; Florian Voss | 24h | 1,172 | 572 |  |  |
| 84 | 3.11 | Copia de la banda sonora final | 12d | 2008-11-26 | 2008-12-11 | 83 | 2008-11-26 | 2008-12-15 | 12d | 0d |  |  | Doug Hampton [50%] | 48h | 921.6 | 921.6 |  |  |
| 85 | 3.12 | Archivado de imagen y sonido finales | 2d | 2008-12-12 | 2008-12-16 | 84 | 2008-12-16 | 2008-12-18 | 2d | 0d |  |  | Doug Hampton [50%]; Laboratorio de edición; Michael Patten | 20h | 515.8 | 515.8 |  |  |
| 86 | 3.13 | Entrega al distribuidor | 1d | 2008-12-16 | 2008-12-17 | 85 | 2008-12-18 | 2008-12-19 | 1d | 0d |  |  | Michael Patten | 8h | 164 | 164 |  |  |
