# Ingeniería

Schedule from MS Project, 2007-01-01 to 2009-05-14, costs in ₡, A marks actual dates.

## Calendars

- Estándar: Mon-Fri 09:00-13:00, 15:00-19:00; Sat-Sun off.

## Resources

| Resource | Rate |
| --- | --- |
| Diseñador | 1500 |
| Ingeniero de proyecto | 2500 |
| Ingeniero de disciplina | 2000 |
| Ingeniero de costos | 1200 |
| Preparador de borradores | 800 |
| Programador | 1000 |
| Patrocinador del proyecto | 3000 |

## Schedule

| ID | WBS | Task | Type | Duration | Start | Finish | Predecessors | Complete | Remaining | Baseline start | Baseline finish | Baseline duration | Baseline 1 start | Baseline 1 finish | Total slack | Free slack | Resources | Work | Actual work | Cost | Baseline cost | Actual cost |
| --- | --- | --- | --- | --- | --- | --- | --- | --- | --- | --- | --- | --- | --- | --- | --- | --- | --- | --- | --- | --- | --- | --- |
| 1 | 1 | **Conceptos** |  | 86d | 2007-01-01 A | 2007-04-30 |  | 22% | 67.26d | 2007-01-01 | 2007-04-20 | 80d | 2007-01-01 | 2007-04-20 | 0d |  |  | 2788h | 576h | 7,293,800 | 5,899,800 | 2,434,000 |
| 2 | 1.1 | **Planeación y control** |  | 20d | 2007-01-01 A | 2007-01-26 A |  | 100% |  | 2007-01-01 | 2007-01-26 | 20d | 2007-01-01 | 2007-01-26 |  |  |  | 320h | 320h | 1,750,000 | 900,000 | 1,750,000 |
| 3 | 1.1.1 | Plan de negocios que identifica la oportunidad del proyecto |  | 5d | 2007-01-01 A | 2007-01-05 A |  | 100% |  | 2007-01-01 | 2007-01-05 | 5d | 2007-01-01 | 2007-01-05 |  |  | Patrocinador del proyecto | 40h | 40h | 370,000 | 120,000 | 370,000 |
| 4 | 1.1.2 | Definir objetivos del proyecto y necesidades de información |  | 5d | 2007-01-08 A | 2007-01-12 A | 3 | 100% |  | 2007-01-08 | 2007-01-12 | 5d | 2007-01-08 | 2007-01-12 |  |  | Patrocinador del proyecto | 40h | 40h | 120,000 | 120,000 | 120,000 |
| 5 | 1.1.3 | Identificar los estándares de la industria para los objetivos del proyecto |  | 5d | 2007-01-15 A | 2007-01-19 A | 4 | 100% |  | 2007-01-15 | 2007-01-19 | 5d | 2007-01-15 | 2007-01-19 |  |  | Patrocinador del proyecto; Ingeniero de proyecto | 80h | 80h | 220,000 | 220,000 | 220,000 |
| 6 | 1.1.4 | Desarrollar la programación conceptual preliminar y el personal |  | 5d | 2007-01-15 A | 2007-01-19 A | 4 | 100% |  | 2007-01-15 | 2007-01-19 | 5d | 2007-01-15 | 2007-01-19 |  |  | Ingeniero de proyecto | 40h | 40h | 450,000 | 100,000 | 450,000 |
| 7 | 1.1.5 | Planeación inicial completada | milestone | 0d | 2007-01-19 A | 2007-01-19 A | 6 | 100% |  | 2007-01-19 | 2007-01-19 | 0d | 2007-01-19 | 2007-01-19 |  |  |  |  |  |  |  |  |
| 8 | 1.1.6 | Desarrollar estrategia de asignación de presupuestos |  | 5d | 2007-01-22 A | 2007-01-26 A | 7 | 100% |  | 2007-01-22 | 2007-01-26 | 5d | 2007-01-22 | 2007-01-26 |  |  | Patrocinador del proyecto | 40h | 40h | 120,000 | 120,000 | 120,000 |
| 9 | 1.1.7 | Desarrollar el modelo de administración y el plan de plantilla |  | 5d | 2007-01-22 A | 2007-01-26 A | 7 | 100% |  | 2007-01-22 | 2007-01-26 | 5d | 2007-01-22 | 2007-01-26 |  |  | Patrocinador del proyecto; Ingeniero de proyecto | 80h | 80h | 470,000 | 220,000 | 470,000 |
| 10 | 1.2 | **Evaluación del sitio** |  | 41d | 2007-01-29 A | 2007-03-26 |  | 30% | 28.52d | 2007-01-22 | 2007-03-16 | 40d | 2007-01-22 | 2007-03-16 | 0d |  |  | 880h | 256h | 2,684,000 | 2,140,000 | 684,000 |
| 11 | 1.2.1 | Identificar sitios potenciales |  | 11d | 2007-01-29 A | 2007-02-12 A | 7 | 100% |  | 2007-01-22 | 2007-02-02 | 10d | 2007-01-22 | 2007-02-02 |  |  | Patrocinador del proyecto; Ingeniero de proyecto | 176h | 176h | 484,000 | 440,000 | 484,000 |
| 12 | 1.2.2 | Definir los requisitos de infraestructura |  | 15d | 2007-02-13 A | 2007-03-05 | 21, 11 | 67% | 5d | 2007-02-05 | 2007-02-23 | 15d | 2007-02-05 | 2007-02-23 | 0d |  | Ingeniero de proyecto | 120h | 80h | 300,000 | 300,000 | 200,000 |
| 13 | 1.2.3 | Definir las necesidades de utilidades |  | 10d | 2007-02-13 | 2007-02-26 | 21, 11 |  |  | 2007-02-05 | 2007-02-16 | 10d | 2007-02-05 | 2007-02-16 | 5d |  | Ingeniero de proyecto; Ingeniero de disciplina | 160h |  | 360,000 | 360,000 |  |
| 14 | 1.2.4 | Identificar el sitio del proyecto |  | 5d | 2007-02-13 | 2007-02-19 | 21, 11 |  |  | 2007-02-05 | 2007-02-09 | 5d | 2007-02-05 | 2007-02-09 | 10d |  | Ingeniero de proyecto; Ingeniero de disciplina | 80h |  | 180,000 | 180,000 |  |
| 15 | 1.2.5 | Evaluar los impactos legales y de medio ambiente |  | 10d | 2007-02-13 | 2007-02-26 | 21, 11 |  |  | 2007-02-05 | 2007-02-16 | 10d | 2007-02-05 | 2007-02-16 | 2d | 0d | Ingeniero de proyecto; Ingeniero de disciplina | 160h |  | 360,000 | 360,000 |  |
| 16 | 1.2.6 | Identificar los requisitos de solicitud de permisos |  | 3d | 2007-02-27 | 2007-03-01 | 15 |  |  | 2007-02-19 | 2007-02-21 | 3d | 2007-02-19 | 2007-02-21 | 2d |  | Ingeniero de proyecto | 24h |  | 560,000 | 60,000 |  |
| 17 | 1.2.7 | Recomendar el sitio |  | 10d | 2007-03-06 | 2007-03-19 | 15, 12, 13, 14, 16 |  |  | 2007-02-26 | 2007-03-09 | 10d | 2007-02-26 | 2007-03-09 | 0d |  | Patrocinador del proyecto; Ingeniero de proyecto | 160h |  | 440,000 | 440,000 |  |
| 18 | 1.2.8 | Revisión del sitio y la planeación |  | 5d | 2007-03-20 | 2007-03-26 | 17 |  |  | 2007-03-12 | 2007-03-16 | 5d | 2007-03-12 | 2007-03-16 | 0d |  |  |  |  |  |  |  |
| 19 | 1.3 | **Definición del alcance** |  | 51d | 2007-01-22 | 2007-04-02 |  |  |  | 2007-01-22 | 2007-03-23 | 45d | 2007-01-22 | 2007-03-23 | 8d |  |  | 616h |  | 1,392,000 | 1,392,000 |  |
| 20 | 1.3.1 | Desarrollar el alcance general de los objetivos del proyecto |  | 5d | 2007-01-22 | 2007-01-26 | 4, 5 |  |  | 2007-01-22 | 2007-01-26 | 5d | 2007-01-22 | 2007-01-26 | 8d | 0d | Patrocinador del proyecto; Ingeniero de proyecto | 80h |  | 220,000 | 220,000 |  |
| 21 | 1.3.2 | Evaluar las necesidades del proyecto y desarrollar una lista de estudio de temas principales |  | 5d | 2007-01-29 | 2007-02-02 | 20 |  |  | 2007-01-29 | 2007-02-02 | 5d | 2007-01-29 | 2007-02-02 | 8d | 0d | Ingeniero de proyecto; Ingeniero de disciplina | 80h |  | 180,000 | 180,000 |  |
| 22 | 1.3.3 | Comenzar los estudios principales |  | 2d | 2007-02-05 | 2007-02-06 | 21 |  |  | 2007-02-05 | 2007-02-06 | 2d | 2007-02-05 | 2007-02-06 | 14d | 0d | Ingeniero de disciplina | 16h |  | 32,000 | 32,000 |  |
| 23 | 1.3.4 | Completar los estudios principales y elaborar recomendaciones |  | 15d | 2007-02-07 | 2007-02-27 | 22 |  |  | 2007-02-07 | 2007-02-27 | 15d | 2007-02-07 | 2007-02-27 | 14d | 0d | Ingeniero de disciplina | 120h |  | 240,000 | 240,000 |  |
| 24 | 1.3.5 | Desarrollar el alcance específico |  | 5d | 2007-02-28 | 2007-03-06 | 23 |  |  | 2007-02-28 | 2007-03-06 | 5d | 2007-02-28 | 2007-03-06 | 14d | 0d | Ingeniero de proyecto; Ingeniero de disciplina | 80h |  | 180,000 | 180,000 |  |
| 25 | 1.3.6 | Preparar la programación conceptual final |  | 10d | 2007-03-07 | 2007-03-20 | 8, 24 |  |  | 2007-03-07 | 2007-03-20 | 10d | 2007-03-07 | 2007-03-20 | 19d |  | Ingeniero de proyecto; Ingeniero de disciplina | 160h |  | 360,000 | 360,000 |  |
| 26 | 1.3.7 | Proporcionar la información del alcance por escrito |  | 5d | 2007-03-27 | 2007-04-02 | 24, 18 |  |  | 2007-03-19 | 2007-03-23 | 5d | 2007-03-19 | 2007-03-23 | 10d |  | Ingeniero de proyecto; Ingeniero de disciplina | 80h |  | 180,000 | 180,000 |  |

Notes:
- 1: Tomar una decisión: / ¿Vamos adelante con el proyecto o no?

| ID | WBS | Task | Type | Duration | Start | Finish | Predecessors | Baseline start | Baseline finish | Baseline duration | Baseline 1 start | Baseline 1 finish | Total slack | Free slack | Resources | Work | Cost | Baseline cost |
| --- | --- | --- | --- | --- | --- | --- | --- | --- | --- | --- | --- | --- | --- | --- | --- | --- | --- | --- |
| 27 | 1.4 | **Apoyo disciplinario** |  | 49d | 2007-02-07 | 2007-04-16 |  | 2007-02-07 | 2007-04-06 | 43d | 2007-02-07 | 2007-04-06 | 0d |  |  | 888h | 1,308,400 | 1,308,400 |
| 28 | 1.4.1 | Crear lista de material que se debe entregar |  | 6d | 2007-02-07 | 2007-02-14 | 22 | 2007-02-07 | 2007-02-14 | 6d | 2007-02-07 | 2007-02-14 | 17d | 0d | Ingeniero de proyecto; Ingeniero de disciplina | 96h | 216,000 | 216,000 |
| 29 | 1.4.2 | Comenzar las hojas del flujo de trabajo y diseñar los criterios |  | 5d | 2007-02-15 | 2007-02-21 | 28 | 2007-02-15 | 2007-02-21 | 5d | 2007-02-15 | 2007-02-21 | 23d |  | Ingeniero de disciplina | 40h | 80,000 | 80,000 |
| 30 | 1.4.3 | Comenzar los diseños específicos de disciplina y la lista de equipamiento |  | 11d | 2007-02-15 | 2007-03-01 | 28 | 2007-02-15 | 2007-03-01 | 11d | 2007-02-15 | 2007-03-01 | 17d |  | Ingeniero de proyecto; Ingeniero de disciplina | 176h | 396,000 | 396,000 |
| 31 | 1.4.4 | Comenzar el diseño conceptual |  | 11d | 2007-02-15 | 2007-03-01 | 28 | 2007-02-15 | 2007-03-01 | 11d | 2007-02-15 | 2007-03-01 | 17d |  | Ingeniero de disciplina; Ingeniero de proyecto; Preparador de borradores | 92h | 79,400 | 79,400 |
| 32 | 1.4.5 | Completar las hojas de flujo de trabajo y el diseño de criterios |  | 15d | 2007-03-27 | 2007-04-16 | 29, 24, 23, 18 | 2007-03-19 | 2007-04-06 | 15d | 2007-03-19 | 2007-04-06 | 0d |  | Ingeniero de disciplina; Preparador de borradores | 240h | 336,000 | 336,000 |
| 33 | 1.4.6 | Completar los diseños específicos de disciplina y la lista de equipamiento |  | 15d | 2007-03-27 | 2007-04-16 | 30, 24, 23, 18 | 2007-03-19 | 2007-04-06 | 15d | 2007-03-19 | 2007-04-06 | 0d |  | Ingeniero de disciplina; Ingeniero de proyecto; Preparador de borradores | 124h | 105,000 | 105,000 |
| 34 | 1.4.7 | Completar el diseño conceptual |  | 15d | 2007-03-27 | 2007-04-16 | 31, 24, 23, 18 | 2007-03-19 | 2007-04-06 | 15d | 2007-03-19 | 2007-04-06 | 0d |  | Preparador de borradores | 120h | 96,000 | 96,000 |
| 35 | 1.5 | **Finalización de la fase conceptual** |  | 10d | 2007-04-17 | 2007-04-30 |  | 2007-04-09 | 2007-04-20 | 10d | 2007-04-09 | 2007-04-20 | 0d |  |  | 84h | 159,400 | 159,400 |
| 36 | 1.5.1 | Preparar el alcance conceptual y estimar la revisión |  | 5d | 2007-04-17 | 2007-04-23 | 25, 8, 9, 26, 32, 33, 34 | 2007-04-09 | 2007-04-13 | 5d | 2007-04-09 | 2007-04-13 | 0d |  | Ingeniero de proyecto; Ingeniero de costos; Preparador de borradores | 44h | 39,400 | 39,400 |
| 37 | 1.5.2 | Evaluar el plan de negocios - incluir los cambios necesarios |  | 5d | 2007-04-24 | 2007-04-30 | 36 | 2007-04-16 | 2007-04-20 | 5d | 2007-04-16 | 2007-04-20 | 0d |  | Patrocinador del proyecto | 40h | 120,000 | 120,000 |
| 38 | 1.5.3 | Fase conceptual completada | milestone | 0d | 2007-04-30 | 2007-04-30 | 37 | 2007-04-20 | 2007-04-20 | 0d | 2007-04-20 | 2007-04-20 | 0d |  |  |  |  |  |
| 39 | 2 | **Definición** |  | 85d | 2007-05-01 | 2007-08-27 |  | 2007-04-23 | 2007-08-17 | 85d | 2007-04-23 | 2007-08-17 | 0d |  |  | 2764h | 5,551,000 | 5,551,000 |
| 40 | 2.1 | **Planeación y control** |  | 15d | 2007-05-01 | 2007-05-21 |  | 2007-04-23 | 2007-05-11 | 15d | 2007-04-23 | 2007-05-11 | 0d |  |  | 320h | 728,000 | 728,000 |
| 41 | 2.1.1 | Revisar el plan conceptual |  | 5d | 2007-05-01 | 2007-05-07 | 38 | 2007-04-23 | 2007-04-27 | 5d | 2007-04-23 | 2007-04-27 | 0d |  | Patrocinador del proyecto; Ingeniero de proyecto | 80h | 220,000 | 220,000 |
| 42 | 2.1.2 | Actualizar el plan de personal del proyecto |  | 5d | 2007-05-01 | 2007-05-07 | 38 | 2007-04-23 | 2007-04-27 | 5d | 2007-04-23 | 2007-04-27 | 55d |  | Ingeniero de proyecto; Ingeniero de disciplina | 80h | 180,000 | 180,000 |
| 43 | 2.1.3 | Identificar el material de ingeniería que se debe entregar en la fase de definición |  | 5d | 2007-05-08 | 2007-05-14 | 41 | 2007-04-30 | 2007-05-04 | 5d | 2007-04-30 | 2007-05-04 | 15d | 0d | Ingeniero de proyecto; Ingeniero de disciplina | 80h | 180,000 | 180,000 |
| 44 | 2.1.4 | Desarrollar el plan de imprevistos del proyecto y los factores de costos indirectos |  | 5d | 2007-05-15 | 2007-05-21 | 43 | 2007-05-07 | 2007-05-11 | 5d | 2007-05-07 | 2007-05-11 | 45d |  | Ingeniero de proyecto; Ingeniero de costos | 80h | 148,000 | 148,000 |
| 45 | 2.2 | **Definición del alcance** |  | 45d | 2007-05-08 | 2007-07-09 |  | 2007-04-30 | 2007-06-29 | 45d | 2007-04-30 | 2007-06-29 | 0d |  |  | 760h | 1,540,000 | 1,540,000 |
| 46 | 2.2.1 | Revisar la lista de estudios |  | 5d | 2007-05-08 | 2007-05-14 | 41 | 2007-04-30 | 2007-05-04 | 5d | 2007-04-30 | 2007-05-04 | 0d |  | Ingeniero de proyecto; Ingeniero de disciplina | 80h | 180,000 | 180,000 |
| 47 | 2.2.2 | Proporcionar los requisitos de diseño |  | 5d | 2007-05-15 | 2007-05-21 | 43 | 2007-05-07 | 2007-05-11 | 5d | 2007-05-07 | 2007-05-11 | 15d |  | Ingeniero de disciplina | 40h | 80,000 | 80,000 |
| 48 | 2.2.3 | Establecer los requisitos de datos de las empresas auxiliares y los presupuestos de equipamiento |  | 10d | 2007-05-15 | 2007-05-28 | 46 | 2007-05-07 | 2007-05-18 | 10d | 2007-05-07 | 2007-05-18 | 0d |  | Ingeniero de proyecto; Ingeniero de disciplina | 160h | 360,000 | 360,000 |
| 49 | 2.2.4 | Definir la lista de equipamiento y sus especificaciones |  | 10d | 2007-05-29 | 2007-06-11 | 41, 48 | 2007-05-21 | 2007-06-01 | 10d | 2007-05-21 | 2007-06-01 | 0d |  | Ingeniero de proyecto; Ingeniero de disciplina | 160h | 360,000 | 360,000 |
| 50 | 2.2.5 | Generar el diseño de canalizaciones y los instrumentos (PID) |  | 20d | 2007-06-12 | 2007-07-09 | 43, 48, 49 | 2007-06-04 | 2007-06-29 | 20d | 2007-06-04 | 2007-06-29 | 0d |  | Ingeniero de disciplina; Diseñador | 320h | 560,000 | 560,000 |

| ID | WBS | Task | Type | Duration | Start | Finish | Predecessors | Baseline start | Baseline finish | Baseline duration | Baseline 1 start | Baseline 1 finish | Total slack | Free slack | Resources | Work | Cost | Baseline cost |
| --- | --- | --- | --- | --- | --- | --- | --- | --- | --- | --- | --- | --- | --- | --- | --- | --- | --- | --- |
| 51 | 2.3 | **Apoyo disciplinario** |  | 40d | 2007-05-15 | 2007-07-09 |  | 2007-05-07 | 2007-06-29 | 40d | 2007-05-07 | 2007-06-29 | 0d |  |  | 880h | 1,600,000 | 1,600,000 |
| 52 | 2.3.1 | Revisar los requisitos legales del organismo de control |  | 20d | 2007-05-15 | 2007-06-11 | 46 | 2007-05-07 | 2007-06-01 | 20d | 2007-05-07 | 2007-06-01 | 0d |  | Ingeniero de disciplina | 160h | 320,000 | 320,000 |
| 53 | 2.3.2 | Generar los planes generales de disposición y del sitio |  | 20d | 2007-06-12 | 2007-07-09 | 47, 43, 48, 49 | 2007-06-04 | 2007-06-29 | 20d | 2007-06-04 | 2007-06-29 | 0d |  | Ingeniero de disciplina; Diseñador | 320h | 560,000 | 560,000 |
| 54 | 2.3.3 | Desarrollar especificaciones, listas y diseños de control específicos de la disciplina |  | 20d | 2007-06-12 | 2007-07-09 | 43, 52, 49 | 2007-06-04 | 2007-06-29 | 20d | 2007-06-04 | 2007-06-29 | 0d |  | Ingeniero de disciplina; Diseñador | 320h | 560,000 | 560,000 |
| 55 | 2.3.4 | Evaluar la información de viabilidad procedente de la información de construcción |  | 10d | 2007-06-26 | 2007-07-09 | 53SS+5%, 50SS+5%, 54SS+5% | 2007-06-18 | 2007-06-29 | 10d | 2007-06-18 | 2007-06-29 | 10d |  | Ingeniero de disciplina | 80h | 160,000 | 160,000 |
| 56 | 2.4 | **Finalización de la fase de definición** |  | 45d | 2007-06-26 | 2007-08-27 |  | 2007-06-18 | 2007-08-17 | 45d | 2007-06-18 | 2007-08-17 | 0d |  |  | 804h | 1,683,000 | 1,683,000 |
| 57 | 2.4.1 | Generar el documento de ámbito (incluida la infraestructura) |  | 20d | 2007-06-26 | 2007-07-23 | 53SS+5%, 50SS+5%, 54SS+5% | 2007-06-18 | 2007-07-13 | 20d | 2007-06-18 | 2007-07-13 | 0d |  | Ingeniero de proyecto; Ingeniero de disciplina | 320h | 720,000 | 720,000 |
| 58 | 2.4.2 | Generar la estimación de capital del proyecto |  | 15d | 2007-06-26 | 2007-07-16 | 53SS+5%, 50SS+5% | 2007-06-18 | 2007-07-06 | 15d | 2007-06-18 | 2007-07-06 | 5d |  | Ingeniero de costos | 120h | 144,000 | 144,000 |
| 59 | 2.4.3 | Establecer la programación del proyecto |  | 10d | 2007-06-26 | 2007-07-09 | 53SS+5%, 50SS+5% | 2007-06-18 | 2007-06-29 | 10d | 2007-06-18 | 2007-06-29 | 10d |  | Ingeniero de proyecto; Programador | 160h | 280,000 | 280,000 |
| 60 | 2.4.4 | Revisar definiciones, ámbito y estimaciones |  | 5d | 2007-07-24 | 2007-07-30 | 57, 58, 59, 42, 48, 53, 44, 50, 55 | 2007-07-16 | 2007-07-20 | 5d | 2007-07-16 | 2007-07-20 | 0d |  | Patrocinador del proyecto; Ingeniero de proyecto; Ingeniero de costos | 44h | 59,000 | 59,000 |
| 61 | 2.4.5 | Ámbito completado - presentar estimación de costos | milestone | 0d | 2007-07-30 | 2007-07-30 | 60 | 2007-07-20 | 2007-07-20 | 0d | 2007-07-20 | 2007-07-20 | 0d |  |  |  |  |  |
| 62 | 2.4.6 | Asignar el dinero del proyecto |  | 20d | 2007-07-31 | 2007-08-27 | 61 | 2007-07-23 | 2007-08-17 | 20d | 2007-07-23 | 2007-08-17 | 0d |  | Patrocinador del proyecto | 160h | 480,000 | 480,000 |
| 63 | 2.4.7 | Proyecto autorizado | milestone | 0d | 2007-08-27 | 2007-08-27 | 62 | 2007-08-17 | 2007-08-17 | 0d | 2007-08-17 | 2007-08-17 | 0d |  |  |  |  |  |
| 64 | 3 | **Diseño** |  | 201.25d | 2007-08-28 | 2008-06-04 |  | 2007-08-20 | 2008-05-27 | 201.25d | 2007-08-20 | 2008-05-27 | 0d |  |  | 20804h | 36,801,000 | 36,801,000 |
| 65 | 3.1 | **Planeación y control** |  | 166d | 2007-08-28 | 2008-04-15 |  | 2007-08-20 | 2008-04-07 | 166d | 2007-08-20 | 2008-04-07 | 0d |  |  | 7364h | 16,915,000 | 16,915,000 |
| 66 | 3.1.1 | Revisar definiciones, ámbito y estimaciones |  | 1d | 2007-08-28 | 2007-08-28 | 63 | 2007-08-20 | 2007-08-20 | 1d | 2007-08-20 | 2007-08-20 | 0d |  | Patrocinador del proyecto; Ingeniero de proyecto | 16h | 44,000 | 44,000 |
| 67 | 3.1.2 | Desarrollar o actualizar procedimientos del proyecto |  | 10d | 2007-08-29 | 2007-09-11 | 66 | 2007-08-21 | 2007-09-03 | 10d | 2007-08-21 | 2007-09-03 | 0d |  | Ingeniero de proyecto | 80h | 200,000 | 200,000 |
| 68 | 3.1.3 | Finalizar la programación del diseño y la construcción |  | 6d | 2007-08-29 | 2007-09-05 | 66 | 2007-08-21 | 2007-08-28 | 6d | 2007-08-21 | 2007-08-28 | 4d | 0d | Programador; Ingeniero de proyecto | 96h | 168,000 | 168,000 |
| 69 | 3.1.4 | Desarrollar y administrar lista de asuntos |  | 100d | 2007-08-29 | 2008-01-15 | 66 | 2007-08-21 | 2008-01-07 | 100d | 2007-08-21 | 2008-01-07 | 98.25d |  | Ingeniero de proyecto | 800h | 2,000,000 | 2,000,000 |
| 70 | 3.1.5 | Obtener el equipamiento con plazo de entrega largo |  | 133d | 2007-08-31 | 2008-03-04 | 84 | 2007-08-23 | 2008-02-25 | 133d | 2007-08-23 | 2008-02-25 | 58d | 30.5d | Ingeniero de proyecto | 1064h | 2,660,000 | 2,660,000 |
| 71 | 3.1.6 | Establecer e implantar el plan de obtención de equipamiento y de contratación |  | 3d | 2007-09-03 | 2007-09-05 | 68SS+5%, 84 | 2007-08-24 | 2007-08-28 | 3d | 2007-08-24 | 2007-08-28 | 4d |  | Patrocinador del proyecto; Ingeniero de proyecto | 48h | 132,000 | 132,000 |
| 72 | 3.1.7 | Planear la fase de diseño y de personal |  | 3d | 2007-09-12 | 2007-09-14 | 66, 67 | 2007-09-04 | 2007-09-06 | 3d | 2007-09-04 | 2007-09-06 | 7.75d |  | Ingeniero de proyecto | 24h | 60,000 | 60,000 |
| 73 | 3.1.8 | Definir la presentación de ingeniería y el contenido de las especificaciones y los diseños |  | 3d | 2007-09-12 | 2007-09-14 | 68SS+5%, 67, 71 | 2007-09-04 | 2007-09-06 | 3d | 2007-09-04 | 2007-09-06 | 0d |  | Ingeniero de proyecto; Ingeniero de disciplina | 48h | 108,000 | 108,000 |
| 74 | 3.1.9 | Implantar el control de documentos |  | 5d | 2007-09-12 | 2007-09-18 | 67 | 2007-09-04 | 2007-09-10 | 5d | 2007-09-04 | 2007-09-10 | 38.25d | 5d | Ingeniero de proyecto | 40h | 100,000 | 100,000 |
| 75 | 3.1.10 | Establecer el seguimiento del proyecto |  | 5d | 2007-09-12 | 2007-09-18 | 67, 71 | 2007-09-04 | 2007-09-10 | 5d | 2007-09-04 | 2007-09-10 | 38.25d | 5d | Ingeniero de proyecto | 40h | 100,000 | 100,000 |
| 76 | 3.1.11 | Desarrollar el control de costo del proyecto y el sistema de valor acumulado |  | 10d | 2007-09-12 | 2007-09-25 | 66, 67 | 2007-09-04 | 2007-09-17 | 10d | 2007-09-04 | 2007-09-17 | 33.25d | 0d | Ingeniero de proyecto; Programador; Ingeniero de costos | 84h | 103,000 | 103,000 |
| 77 | 3.1.12 | Finalizar la lista de material que se debe entregar |  | 10d | 2007-09-12 | 2007-09-26 | 66, 73SS+2.5%, 71 | 2007-09-04 | 2007-09-18 | 10d | 2007-09-04 | 2007-09-18 | 0d |  | Ingeniero de proyecto; Ingeniero de disciplina | 160h | 360,000 | 360,000 |
| 78 | 3.1.13 | Implantar el sistema de informes del proyecto |  | 145d | 2007-09-26 | 2008-04-15 | 76, 67, 74, 75 | 2007-09-18 | 2008-04-07 | 145d | 2007-09-18 | 2008-04-07 | 33.25d |  | Ingeniero de proyecto | 1160h | 2,900,000 | 2,900,000 |
| 79 | 3.1.14 | Aprobación de facturas y de pagos por contratos |  | 100d | 2007-10-10 | 2008-02-26 | 85 | 2007-10-02 | 2008-02-18 | 100d | 2007-10-02 | 2008-02-18 | 68.25d |  | Ingeniero de proyecto | 800h | 2,000,000 | 2,000,000 |
| 80 | 3.1.15 | Obtener el equipamiento |  | 123d | 2007-10-17 | 2008-04-04 | 85, 88SS+5% | 2007-10-09 | 2008-03-27 | 123d | 2007-10-09 | 2008-03-27 | 27.5d | 0d | Ingeniero de proyecto | 984h | 2,460,000 | 2,460,000 |
| 81 | 3.1.16 | Implantar la aceleración de procesos, incluidos los diseños de las empresas auxiliares |  | 100d | 2007-10-17 | 2008-03-04 | 85, 88SS+5% | 2007-10-09 | 2008-02-25 | 100d | 2007-10-09 | 2008-02-25 | 63.25d |  | Ingeniero de proyecto; Programador | 1600h | 2,800,000 | 2,800,000 |
| 82 | 3.1.17 | Plan de enseñanza inicial |  | 20d | 2008-02-18 | 2008-03-14 | 89 | 2008-02-08 | 2008-03-06 | 20d | 2008-02-08 | 2008-03-06 | 55.25d |  | Ingeniero de proyecto; Ingeniero de disciplina | 320h | 720,000 | 720,000 |

| ID | WBS | Task | Duration | Start | Finish | Predecessors | Baseline start | Baseline finish | Baseline duration | Baseline 1 start | Baseline 1 finish | Total slack | Free slack | Resources | Work | Cost | Baseline cost |
| --- | --- | --- | --- | --- | --- | --- | --- | --- | --- | --- | --- | --- | --- | --- | --- | --- | --- |
| 83 | 3.2 | **Ajuste del ámbito** | 123d | 2007-08-29 | 2008-02-15 |  | 2007-08-21 | 2008-02-07 | 123d | 2007-08-21 | 2008-02-07 | 5d |  |  | 2032h | 3,992,000 | 3,992,000 |
| 84 | 3.2.1 | Actualizar los criterios de diseño del proyecto | 2d | 2007-08-29 | 2007-08-30 | 66 | 2007-08-21 | 2007-08-22 | 2d | 2007-08-21 | 2007-08-22 | 5d | 0d | Ingeniero de proyecto; Ingeniero de disciplina | 32h | 72,000 | 72,000 |
| 85 | 3.2.2 | Asunto de diseño: lista de equipamientos | 30d | 2007-08-29 | 2007-10-09 | 66 | 2007-08-21 | 2007-10-01 | 30d | 2007-08-21 | 2007-10-01 | 27.5d | 0d | Ingeniero de disciplina | 240h | 480,000 | 480,000 |
| 86 | 3.2.3 | Asunto para diseño de disciplina: canalización y diseño de los instrumentos (PID) | 30d | 2007-09-17 | 2007-10-26 | 73 | 2007-09-07 | 2007-10-18 | 30d | 2007-09-07 | 2007-10-18 | 35.25d | 0d | Ingeniero de disciplina; Diseñador | 480h | 840,000 | 840,000 |
| 87 | 3.2.4 | Asunto para el diseño de la disciplina: diseño de administración general (AG) y plan del sitio | 30d | 2007-09-17 | 2007-10-26 | 73 | 2007-09-07 | 2007-10-18 | 30d | 2007-09-07 | 2007-10-18 | 35.25d | 0d | Ingeniero de disciplina; Diseñador | 480h | 840,000 | 840,000 |
| 88 | 3.2.5 | Especificaciones del equipamiento, ofertas, selección de empresas auxiliares | 40d | 2007-09-19 | 2007-11-13 | 73, 85SS+5% | 2007-09-11 | 2007-11-05 | 40d | 2007-09-11 | 2007-11-05 | 27.5d | 0d | Ingeniero de proyecto; Ingeniero de disciplina | 640h | 1,440,000 | 1,440,000 |
| 89 | 3.2.6 | Procesar las descripciones funcionales del equipamiento | 20d | 2008-01-21 | 2008-02-15 | 106SS+7.5% | 2008-01-11 | 2008-02-07 | 20d | 2008-01-11 | 2008-02-07 | 35.25d | 0d | Ingeniero de disciplina | 160h | 320,000 | 320,000 |
| 90 | 3.3 | **Apoyo disciplinario** | 200.25d | 2007-08-29 | 2008-06-04 |  | 2007-08-21 | 2008-05-27 | 200.25d | 2007-08-21 | 2008-05-27 | 0d |  |  | 11408h | 15,894,000 | 15,894,000 |
| 91 | 3.3.1 | Establecer la disciplina por que se regirán los requisitos del código | 2d | 2007-08-29 | 2007-08-30 | 66 | 2007-08-21 | 2007-08-22 | 2d | 2007-08-21 | 2007-08-22 | 18.75d |  | Ingeniero de disciplina | 16h | 32,000 | 32,000 |
| 92 | 3.3.2 | Revisar y finalizar los estándares de disciplina y las especificaciones | 5d | 2007-09-26 | 2007-10-03 | 73, 91, 72, 77 | 2007-09-18 | 2007-09-25 | 5d | 2007-09-18 | 2007-09-25 | 0d |  | Ingeniero de disciplina | 40h | 80,000 | 80,000 |
| 93 | 3.3.3 | **Comenzar el diseño de la disciplina** | 55d | 2007-10-03 | 2007-12-19 |  | 2007-09-25 | 2007-12-11 | 55d | 2007-09-25 | 2007-12-11 | 0d |  |  | 3280h | 5,740,000 | 5,740,000 |
| 94 | 3.3.3.1 | Comenzar el diseño de la arquitectura | 25d | 2007-10-03 | 2007-11-07 | 92 | 2007-09-25 | 2007-10-30 | 25d | 2007-09-25 | 2007-10-30 | 0d |  | Ingeniero de disciplina; Diseñador | 400h | 700,000 | 700,000 |
| 95 | 3.3.3.2 | Comenzar el diseño civil | 30d | 2007-10-10 | 2007-11-21 | 94SS+5d | 2007-10-02 | 2007-11-13 | 30d | 2007-10-02 | 2007-11-13 | 0d |  | Ingeniero de disciplina; Diseñador | 480h | 840,000 | 840,000 |
| 96 | 3.3.3.3 | Comenzar el diseño mecánico | 30d | 2007-10-17 | 2007-11-28 | 95SS+5d | 2007-10-09 | 2007-11-20 | 30d | 2007-10-09 | 2007-11-20 | 0d |  | Ingeniero de disciplina; Diseñador | 480h | 840,000 | 840,000 |
| 97 | 3.3.3.4 | Comenzar el diseño de canalizaciones | 30d | 2007-10-24 | 2007-12-05 | 96SS+5d | 2007-10-16 | 2007-11-27 | 30d | 2007-10-16 | 2007-11-27 | 0d |  | Ingeniero de disciplina; Diseñador | 480h | 840,000 | 840,000 |
| 98 | 3.3.3.5 | Comenzar el diseño estructural | 30d | 2007-10-10 | 2007-11-21 | 94SS+5d | 2007-10-02 | 2007-11-13 | 30d | 2007-10-02 | 2007-11-13 | 20d |  | Ingeniero de disciplina; Diseñador | 480h | 840,000 | 840,000 |
| 99 | 3.3.3.6 | Comenzar el diseño eléctrico | 30d | 2007-10-31 | 2007-12-12 | 97SS+5d | 2007-10-23 | 2007-12-04 | 30d | 2007-10-23 | 2007-12-04 | 0d |  | Ingeniero de disciplina; Diseñador | 480h | 840,000 | 840,000 |
| 100 | 3.3.3.7 | Comenzar el diseño de instrumentación | 30d | 2007-11-07 | 2007-12-19 | 99SS+5d | 2007-10-30 | 2007-12-11 | 30d | 2007-10-30 | 2007-12-11 | 0d |  | Ingeniero de disciplina; Diseñador | 480h | 840,000 | 840,000 |
| 101 | 3.3.4 | Implantar la primera revisión de calidad | 5d | 2007-12-10 | 2007-12-17 | 94SS+7.5%, 95SS+7.5%, 96SS+7.5%, 97SS+7.5%, 98SS+7.5%, 99SS+7.5%, 100SS+7.5% | 2007-11-30 | 2007-12-07 | 5d | 2007-11-30 | 2007-12-07 | 0d |  | Ingeniero de disciplina | 40h | 80,000 | 80,000 |
| 102 | 3.3.5 | Revisión del diseño de empresas auxiliares (todas las disciplinas) | 60d | 2007-11-28 | 2008-02-20 | 80SS+2.5%, 70SS+2.5% | 2007-11-20 | 2008-02-12 | 60d | 2007-11-20 | 2008-02-12 | 27.5d | 0d | Ingeniero de disciplina | 480h | 960,000 | 960,000 |
| 103 | 3.3.6 | Certificación del diseño de empresas auxiliares (todas las disciplinas) | 5d | 2008-02-20 | 2008-02-27 | 102 | 2008-02-12 | 2008-02-19 | 5d | 2008-02-12 | 2008-02-19 | 27.5d |  | Ingeniero de disciplina; Ingeniero de proyecto | 80h | 180,000 | 180,000 |
| 104 | 3.3.7 | Revisión cruzada de la ingeniería de las disciplinas | 5d | 2007-12-10 | 2007-12-17 | 94SS+7.5%, 95SS+7.5%, 96SS+7.5%, 97SS+7.5%, 98SS+7.5%, 99SS+7.5%, 100SS+7.5% | 2007-11-30 | 2007-12-07 | 5d | 2007-11-30 | 2007-12-07 | 0d |  | Ingeniero de disciplina; Diseñador | 80h | 140,000 | 140,000 |
| 105 | 3.3.8 | Completar la lista de equipamientos | 90d | 2007-10-10 | 2008-02-12 | 85 | 2007-10-02 | 2008-02-04 | 90d | 2007-10-02 | 2008-02-04 | 38.25d |  | Ingeniero de disciplina; Ingeniero de proyecto | 1440h | 3,240,000 | 3,240,000 |
| 106 | 3.3.9 | Completar los PID | 80d | 2007-10-29 | 2008-02-15 | 86 | 2007-10-19 | 2008-02-07 | 80d | 2007-10-19 | 2008-02-07 | 35.25d | 0d | Ingeniero de disciplina; Diseñador; Preparador de borradores | 644h | 519,000 | 519,000 |
| 107 | 3.3.10 | Completar los AG y el plan del sitio | 80d | 2007-10-29 | 2008-02-15 | 87 | 2007-10-19 | 2008-02-07 | 80d | 2007-10-19 | 2008-02-07 | 35.25d |  | Ingeniero de disciplina; Diseñador; Preparador de borradores | 644h | 519,000 | 519,000 |

Notes:
- 94: Esta tarea incluye lo siguiente: / Proyecciones / Planos de planta / Elevaciones / Programación de finalización
- 95: Esta tarea incluye lo siguiente: / Plano parcelario / Erosión / Gradación / Tubería subterránea / Infraestructura
- 96: Esta tarea incluye lo siguiente: / Depósitos / Equipo especial / Calefacción, ventilación y aire acondicionado / Manipulación de materiales / Bombas
- 97: Esta tarea incluye lo siguiente: / PID (identificaciones de proyecto) / Planos / Secciones / ISO / Fuego / Cañerías / Colgadores / Cálculos de tensión / Lista de líneas de tuberías
- 98: Esta tarea incluye lo siguiente: / Acero / Losas / Soporte de equipo / Cimientos
- 99: Esta tarea incluye lo siguiente: / Planos de suministro eléctrico / Centros de control de motor (MCC) / Controles lógicos programables (PLC) / Tierra / Iluminación / Comunicación / Elemental
- 100: Esta tarea incluye lo siguiente: / PID / Hojas de datos / Bucles / Lógica / Ubicaciones / Índice

| ID | WBS | Task | Type | Duration | Start | Finish | Predecessors | Baseline start | Baseline finish | Baseline duration | Baseline 1 start | Baseline 1 finish | Total slack | Free slack | Resources | Work | Cost | Baseline cost |
| --- | --- | --- | --- | --- | --- | --- | --- | --- | --- | --- | --- | --- | --- | --- | --- | --- | --- | --- |
| 108 | 3.3.11 | **Completar el diseño de las disciplinas** |  | 80d | 2007-12-17 | 2008-04-07 |  | 2007-12-07 | 2008-03-28 | 80d | 2007-12-07 | 2008-03-28 | 0d |  |  | 4108h | 3,313,000 | 3,313,000 |
| 109 | 3.3.11.1 | Completar el diseño de la arquitectura |  | 70d | 2007-12-17 | 2008-03-24 | 104, 87, 101 | 2007-12-07 | 2008-03-14 | 70d | 2007-12-07 | 2008-03-14 | 10d | 7.5d | Ingeniero de disciplina; Diseñador; Preparador de borradores | 564h | 455,000 | 455,000 |
| 110 | 3.3.11.2 | Completar el diseño civil |  | 70d | 2007-12-17 | 2008-03-24 | 104, 87, 101 | 2007-12-07 | 2008-03-14 | 70d | 2007-12-07 | 2008-03-14 | 10d |  | Ingeniero de disciplina; Diseñador; Preparador de borradores | 564h | 455,000 | 455,000 |
| 111 | 3.3.11.3 | Completar el diseño mecánico |  | 70d | 2007-12-17 | 2008-03-24 | 104, 87, 101 | 2007-12-07 | 2008-03-14 | 70d | 2007-12-07 | 2008-03-14 | 10d | 7.5d | Ingeniero de disciplina; Diseñador; Preparador de borradores | 564h | 455,000 | 455,000 |
| 112 | 3.3.11.4 | Completar el diseño estructural |  | 70d | 2007-12-17 | 2008-03-24 | 104, 87, 101 | 2007-12-07 | 2008-03-14 | 70d | 2007-12-07 | 2008-03-14 | 10d | 7.5d | Ingeniero de disciplina; Diseñador; Preparador de borradores | 564h | 455,000 | 455,000 |
| 113 | 3.3.11.5 | Completar el diseño de canalización |  | 70d | 2007-12-17 | 2008-03-24 | 104, 86, 101 | 2007-12-07 | 2008-03-14 | 70d | 2007-12-07 | 2008-03-14 | 10d | 7.5d | Ingeniero de disciplina; Diseñador; Preparador de borradores | 564h | 455,000 | 455,000 |
| 114 | 3.3.11.6 | Completar el diseño eléctrico |  | 80d | 2007-12-17 | 2008-04-07 | 104, 86, 101 | 2007-12-07 | 2008-03-28 | 80d | 2007-12-07 | 2008-03-28 | 0d |  | Ingeniero de disciplina; Diseñador; Preparador de borradores | 644h | 519,000 | 519,000 |
| 115 | 3.3.11.7 | Completar el diseño de la instrumentación |  | 80d | 2007-12-17 | 2008-04-07 | 104, 86, 101 | 2007-12-07 | 2008-03-28 | 80d | 2007-12-07 | 2008-03-28 | 0d |  | Ingeniero de disciplina; Diseñador; Preparador de borradores | 644h | 519,000 | 519,000 |
| 116 | 3.3.12 | Implantar la segunda revisión de calidad |  | 5d | 2008-03-10 | 2008-03-17 | 109SS+7.5%, 111SS+7.5%, 112SS+7.5%, 113SS+7.5%, 114SS+7.5% | 2008-02-29 | 2008-03-07 | 5d | 2008-02-29 | 2008-03-07 | 15d |  | Ingeniero de disciplina | 40h | 80,000 | 80,000 |
| 117 | 3.3.13 | Implantar revisiones de cumplimiento con el código y la seguridad |  | 10d | 2008-03-10 | 2008-03-24 | 109SS+7.5%, 111SS+7.5%, 112SS+7.5%, 113SS+7.5%, 114SS+7.5% | 2008-02-29 | 2008-03-14 | 10d | 2008-02-29 | 2008-03-14 | 10d |  | Ingeniero de disciplina | 80h | 160,000 | 160,000 |
| 118 | 3.3.14 | **Fase de diseño completada** |  | 42d | 2008-04-07 | 2008-06-04 |  | 2008-03-28 | 2008-05-27 | 42d | 2008-03-28 | 2008-05-27 | 0d |  |  | 436h | 851,000 | 851,000 |
| 119 | 3.3.14.1 | Comprobar y volver a escribir borradores de diseño y listas (todas las disciplinas) |  | 15d | 2008-04-07 | 2008-04-28 | 109, 110, 111, 112, 113, 114, 115, 89, 103, 105, 106, 107, 116, 117 | 2008-03-28 | 2008-04-18 | 15d | 2008-03-28 | 2008-04-18 | 0d |  | Ingeniero de disciplina; Diseñador; Preparador de borradores | 124h | 103,000 | 103,000 |
| 120 | 3.3.14.2 | Elaborar borradores de permisos y cálculos de cumplimiento del código (todas las disciplinas) |  | 5d | 2008-04-28 | 2008-05-05 | 119 | 2008-04-18 | 2008-04-25 | 5d | 2008-04-18 | 2008-04-25 | 0d |  | Ingeniero de disciplina; Ingeniero de proyecto | 80h | 180,000 | 180,000 |
| 121 | 3.3.14.3 | Autorizar a ingeniería para tramitar permisos, licitación y construcción |  | 15d | 2008-05-05 | 2008-05-26 | 120 | 2008-04-25 | 2008-05-16 | 15d | 2008-04-25 | 2008-05-16 | 0d |  | Ingeniero de proyecto | 120h | 300,000 | 300,000 |
| 122 | 3.3.14.4 | Selección de personal auxiliar y revisión de contratos |  | 5d | 2008-05-26 | 2008-06-02 | 121 | 2008-05-16 | 2008-05-23 | 5d | 2008-05-16 | 2008-05-23 | 0d |  | Ingeniero de disciplina; Ingeniero de proyecto | 80h | 180,000 | 180,000 |
| 123 | 3.3.14.5 | Proyecto completado - informe de finalización, preparar bocetos de registro |  | 2d | 2008-06-02 | 2008-06-04 | 122, 69, 78, 80, 81, 79, 82, 70 | 2008-05-23 | 2008-05-27 | 2d | 2008-05-23 | 2008-05-27 | 0d |  | Ingeniero de proyecto; Patrocinador del proyecto | 32h | 88,000 | 88,000 |
| 124 | 4 | **Construcción** |  | 246d | 2008-06-04 | 2009-05-14 | 123 | 2008-05-27 | 2009-05-06 | 246d | 2008-05-27 | 2009-05-06 | 0d |  |  |  |  |  |
| 125 | 4.1 | Seleccionar personal auxiliar de construcción |  | 30d | 2008-06-04 | 2008-07-16 | 123 | 2008-05-27 | 2008-07-08 | 30d | 2008-05-27 | 2008-07-08 | 0d |  |  |  |  |  |
| 126 | 4.2 | Traslado al lugar de trabajo |  | 20d | 2008-07-16 | 2008-08-13 | 125 | 2008-07-08 | 2008-08-05 | 20d | 2008-07-08 | 2008-08-05 | 0d |  |  |  |  |  |
| 127 | 4.3 | Construcción |  | 196d | 2008-08-13 | 2009-05-14 | 126 | 2008-08-05 | 2009-05-06 | 196d | 2008-08-05 | 2009-05-06 | 0d |  |  |  |  |  |
| 128 | 4.4 | Construcción completada | milestone | 0d | 2009-05-14 | 2009-05-14 | 127 | 2009-05-06 | 2009-05-06 | 0d | 2009-05-06 | 2009-05-06 | 0d |  |  |  |  |  |
